# 3GPP_Release-2000

Schedule from MS Project, 2000-01-03 to 2005-12-30, A marks actual dates.

## Calendars

- Standard: Mon-Fri 08:00-12:00, 13:00-17:00; Sat-Sun off.

## Resources

| Resource |
| --- |
| NP |
| N1 |
| N2 |
| N3 |
| N4 |
| N5 |
| TP |
| T1 |
| T2 |
| T3 |
| RP |
| R1 |
| R2 |
| R3 |
| R4 |
| SP |
| S1 |
| S2 |
| S3 |
| S4 |
| S5 |
| PCG |
| GP |
| No |
| CN4 |
| ? |
| WG G2 |
| G2 |
| G1 |
| G4 |
| G3 |
| All |
| Generic |
| MLST |
| G5 |
| S3; G2 |
| WG T2 |
| GP,G1 |
| G4,G5 |
| OMA |
| GP-G2 |
| Yes |
| GP; |
| N4; |
| GP; N1 |
| CT5 |
| C1 |

## Schedule

| ID | WBS | Task | Duration | Start | Finish | Complete | Remaining | Baseline start | Baseline finish | Baseline duration | Total slack | Constraint | Resources | Work | Actual work | Text9 | Text1 | Text4 | Text5 | Text6 | Text7 | Text8 | Text11 | Text3 | Text2 | Text10 |
| --- | --- | --- | --- | --- | --- | --- | --- | --- | --- | --- | --- | --- | --- | --- | --- | --- | --- | --- | --- | --- | --- | --- | --- | --- | --- | --- |
| 1 | 1 | VERSION 2005 June 2nd | 1d | 2000-01-03 | 2000-01-03 |  |  | 2000-01-03 | 2000-01-03 | 1d | 1564d |  |  |  |  | 2044 |  |  |  |  |  |  |  |  |  |  |
| 2 | 2 | "CTRL + a" to display all the 3GPP fields | 1d | 2000-01-03 | 2000-01-03 |  |  | 2000-01-03 | 2000-01-03 | 1d | 2568d |  |  |  |  | 1462 |  |  |  |  |  |  |  |  |  |  |
| 3 | 3 | Content of Rel-6, frozen at SA#26 | 1d | 2000-01-03 | 2000-01-03 |  |  | 2000-01-03 | 2000-01-03 | 1d | 1564d |  |  |  |  | 2058 |  |  |  |  |  |  |  |  |  |  |
| 5 | 4 | Rel-6 Evolutions of the transport in the UTRAN | 218d | 2003-03-03 | 2003-12-31 |  |  | 2003-03-03 | 2003-12-31 | 218d | 1526d | start no earlier than 2003-03-03 | RP | 1744h |  | Feat | ETRAN | Francois Courau, Alcatel | francois.courau@alcatel.fr | Rel-6 | TSG | Cesar | Generic |  |  |  |
| 6 | 8 | **Rel-6 Improvements of Radio Interface** | 1262d? | 2000-08-14 A | 2005-06-15 | 96% | 54.74d? | 2000-08-14 | 2005-06-15 | 1262d? | 143d |  | RP | 36040h | 31686.1h |  | RInImp |  |  | Rel-6 | TSG | Cesar |  |  |  |  |
| 7 | 5.1 | Improving Receiver Performance Requirements for the FDD UE | 401d | 2002-03-08 A | 2003-09-19 A | 100% |  | 2002-03-08 | 2003-09-19 | 401d |  | start no earlier than 2002-03-08 | R4 | 3208h | 3208h | BB | RInImp-UERecPerf | Shimon Moshavi, Intel | shimon.moshavi@INTEL.COM | Rel-6 | TSG |  | Active | TS25.101 |  |  |
| 8 | 8.2 | **Base station classification** | 603d | 2000-08-14 A | 2002-12-04 A | 100% |  | 2000-08-14 | 2002-12-04 | 603d |  |  | R4 | 9648h | 9648h |  | RInImp-BSClass |  |  | Rel-6 | TSG |  |  |  |  |  |
| 9 | 8.2.1 | FDD Base station classification | 603d | 2000-08-14 A | 2002-12-04 A | 100% |  | 2000-08-14 | 2002-12-04 | 603d |  | finish no earlier than 2002-12-04 | R4 | 4824h | 4824h | 1476 | RInImp-BSClass-FDD | A. Toskala, Nokia |  | Rel-6 | TSG |  |  | TS25.104, TS25.141 | BaAs |  |
| 10 | 5.3 | UMTS-850 | 266d | 2002-12-06 A | 2003-12-12 A | 100% |  | 2002-12-06 | 2003-12-12 | 266d |  | finish no earlier than 2003-12-15 | R4 | 2128h | 2128h | BB | RInImp-UMTS850 | Don Zelmer, Cingular | don.zelmer@cingular.com | Rel-6 | TSG | MCC_RAN | Active | TS25.101, 25.104, 25.133, 25.141, 25.307, 25.331, TR25.942 |  |  |
| 11 | 5.4 | DS-CDMA introduction in the 800 MHz band | 196d | 2003-03-14 A | 2003-12-12 A | 100% |  | 2003-03-14 | 2003-12-12 | 196d |  | finish no earlier than 2003-12-15 | R4 | 1568h | 1568h | BB | RInImp-UMTS800 | Takehiro Nakamura, NTT DoCoMo | takehiro@wsp.yrp.nttdocomo.co.jp | Rel-6 | TSG | MCC_RAN | Active | TS25.101, 25.104, 25.133, 25.141, 25.307, 25.331 |  |  |
| 12 | 5.5 | UMTS 1.7/2.1 GHz | 261d | 2003-03-14 A | 2004-03-12 A | 100% |  | 2003-03-14 | 2004-03-12 | 261d |  | finish no earlier than 2004-03-15 | R4 | 2088h | 2088h | BB | RInImp-UMTS1721 | Jussi Numminen, Nokia | jussi.numminen@NOKIA.COM | Rel-6 | TSG | MCC RAN | Active | TS25.101, 25.104, 25.133, 25.141, 25.307, 25.331 |  |  |
| 13 | 5.6 | **Improved Receiver Performance Requirements for HSDPA** | 392d? | 2003-12-15 A | 2005-06-15 | 81% | 73.36d? | 2003-12-15 | 2005-06-15 | 392d? | 143d |  | R4 | 7304h | 3388h |  | RInImp-HSPerf | Jussi Numminen, Nokia | jussi.numminen@NOKIA.COM | Rel-6 | TSG | MCC RAN |  |  |  |  |
| 14 | 5.6.1 | Improved Minimum Performance Requirements for HSDPA UE categories 7 and 8 | 195d? | 2004-09-15 A | 2005-06-15 | 50% | 97.5d? | 2004-09-15 | 2005-06-15 | 195d? | 516d | finish no earlier than 2005-06-15 | R4 | 1560h | 780h |  | RInImp-HSPerf-10code | Jussi Numminen, Nokia | jussi.numminen@nokia.com | Rel-6 | TSG | MCC_RAN |  | TS25.101 |  |  |
| 15 | 5.6.2 | Performance Requirements of Receive Diversity for HSDPA | 326d | 2003-12-15 A | 2005-03-14 A | 100% |  | 2003-12-15 | 2005-03-15 | 326d |  | finish no earlier than 2005-03-14 | R4 | 2608h | 2608h |  | RInImp-HSPerf-RxDiv | Takehiro Nakamura (NTT DoCoMo) | takehiro@wsp.yrp.nttdocomo.co.jp | Rel-6 | TSG | MCC RAN |  | TS25.101 |  |  |
| 16 | 6 | **Rel-6 RAN Feasibility Studies** | 1196d? | 2000-08-14 A | 2005-03-14 | 99% | 0d? | 2000-08-14 | 2005-03-15 | 1196d? | 0d |  | RP | 43048h | 36488h |  |  |  |  | Rel-6 |  | Cesar |  |  |  |  |
| 17 | 6.1 | FS of the improved access to UE measurement data for CRNC to support TDD RRM | 270d? | 2002-12-06 A | 2003-12-18 A | 100% |  | 2002-12-06 | 2003-12-18 | 270d? |  | finish no earlier than 2003-09-19 | R3 | 2160h | 2160h |  | RANimp-RRMopt-FSUEMsD | Jim Miller, Interdigital | jim.miller@interdigital.com | Rel-6 | TSG |  |  |  |  | SP-24 |
| 18 | 6.2 | FS on Radio link performance enhancements | 1067d | 2000-08-14 A | 2004-09-14 A | 100% |  | 2000-08-14 | 2004-09-14 | 1067d |  | finish no earlier than 2004-09-14 | R1 | 8536h | 8536h | SI | RInImp-Rlperf | Antti Toskala, Nokia Networks | antti.toskala@nokia.com | Rel-6 | TSG | MCC_RAN | Active | TR25.899 |  |  |
| 19 | 6.3 | FS on Improvement of inter-frequency and inter-system measurements for 1.28 Mcps TDD | 461d | 2001-12-14 A | 2003-09-19 A | 100% |  | 2001-12-14 | 2003-09-19 | 461d |  | start no earlier than 2001-12-14 | R1 | 3688h | 3688h | SI | RInImp-IfIsMLCR | Li Xiao Qiang, SAMSUNG | xqli@samsung.co.kr | Rel-6 | TSG |  | Active | TR25.888 |  |  |
| 20 | 6.4 | FS for the analysis of OFDM for UTRAN enhancement | 526d | 2002-06-10 A | 2004-06-14 A | 100% |  | 2002-06-10 | 2004-06-14 | 526d |  | start no earlier than 2002-06-10 | R1 | 4208h | 4208h | SI | RInImp-FSOFDM | Sarah Boumendil, Nortel | boumendi@nortelnetworks.com | Rel-6 | TSG | MCC_RAN | Active | TR25.892 |  |  |
| 21 | 6.5 | FS on Uplink Enhancements for Dedicated Transport Channels | 396d | 2002-09-06 A | 2004-03-12 A | 100% |  | 2002-09-06 | 2004-03-12 | 396d |  | finish no earlier than 2004-03-12 | R1 | 3168h | 3168h | SI | RInImp-FSUpDTrCh | Karri Ranta-aho, Nokia | Karri.Ranta-aho@nokia.com | Rel-6 | TSG | MCC_RAN | Active | TR25.896 |  |  |
| 22 | 6.6 | FS on Analysis on Higher Chip Rates for UTRA TDD evolutions | 528d | 2002-09-06 A | 2004-09-14 A | 100% |  | 2002-09-06 | 2004-09-14 | 528d |  | finish no earlier than 2004-09-14 | R1 | 4224h | 4224h | SI | RInImp-FSVHCRTDD | Tim Wilkinson, IPWireless | mbeale@ipwireless.com | Rel-6 | TSG | MCC_RAN | Active | TR25.895 |  |  |
| 23 | 6.7 | FS on Low Output Powers for general purpose FDD BSs | 128d | 2003-06-13 A | 2004-03-12 A | 100% |  | 2003-06-13 | 2004-03-12 | 128d |  | finish no earlier than 2004-03-12 | R3 | 1024h | 1024h | SI | RInImp-FSLoPw | Ana Burgos, Telefonica | burgos_a@tsm.es | Rel-6 | TSG | MCC_RAN | Active | TR25.807 |  |  |
| 24 | 6.8 | FS on Uplink enhancements for UTRA TDD | 462d | 2003-06-06 A | 2005-03-14 A | 100% |  | 2003-06-06 | 2005-03-15 | 462d |  | finish no earlier than 2005-03-14 | R1 | 3696h | 3696h | SI | RInImp-FSUpEnhTDD | Marian Rudolf, Interdigital | Marian.Rudolf@InterDigital.com | Rel-6 | TSG | MCC_RAN | Active | TR25.804 |  |  |
| 25 | 8.8 | FS on UE antenna efficiency test methods performance requirements (2) | 131d | 2002-03-08 A | 2002-09-06 A | 100% |  | 2002-03-08 | 2002-09-06 | 131d |  | finish no earlier than 2002-09-06 | R4 | 1048h | 1048h |  | RInImp-UEAnTM2 | Alf Ahlström, Allgon |  | Rel-6 | TSG |  |  |  |  |  |
| 26 | 9.4 | Deleted - FS on the evolution of the UTRAN architecture | 592d | 2002-09-09 A | 2004-12-15 A | 100% |  | 2002-09-09 | 2004-12-15 | 592d |  | finish no earlier than 2004-12-15 | R3 | 4736h | 4736h |  | RANimp-FSEvo | Woonhee Hwang, Nokia | Antti.Toskala@nokia.com | Rel-6 | TSG | MCC_RAN |  |  |  |  |

Notes:
- 5: Generic feature
- 6: This is a generic feature without particular end date
- 14: Approved at RP#25 as RP-040375
- 18: Study finished at RP#25
- 22: Study finished at RP#25
- 25: The RInImp-UEAnTM FS was re-opened at TSG RAN#15 upon request from WG4
- 26: Study Closed, work will continue within the FS on evolved UTRA and UTRAN

| ID | WBS | Task | Type | Duration | Start | Finish | Complete | Remaining | Baseline start | Baseline finish | Baseline duration | Total slack | Constraint | Resources | Work | Actual work | Text1 | Text4 | Text6 | Text7 | Text8 | Text9 | Text11 | Text3 | Text5 | Text2 | Text12 | Text10 |
| --- | --- | --- | --- | --- | --- | --- | --- | --- | --- | --- | --- | --- | --- | --- | --- | --- | --- | --- | --- | --- | --- | --- | --- | --- | --- | --- | --- | --- |
| 27 | 7 | **FDD Enhanced Uplink** |  | 327d | 2004-03-15 A | 2005-06-15 | 84% | 53.18d | 2004-03-15 | 2005-06-15 | 327d | 143d |  | RP | 13072h | 8755.6h | EDCH | Joakim Bergström (Ericsson) | Rel-6 | TSG | Cesar | Feat | Active |  |  |  |  |  |
| 28 | 7.1 | FDD Enhanced Uplink - Stage 2 |  | 197d | 2004-03-15 A | 2004-12-14 A | 100% |  | 2004-03-15 | 2004-12-14 | 197d |  | finish no earlier than 2004-12-14 | R2 | 1576h | 1576h | EDCH-Stage2 |  | Rel-6 | TSG |  |  |  | TS 25.309 |  |  |  |  |
| 29 | 7.2 | FDD Enhanced Uplink - Physical Layer |  | 261d | 2004-03-15 A | 2005-03-14 A | 100% |  | 2004-03-15 | 2005-03-15 | 261d |  | finish no earlier than 2005-03-14 | R1 | 2088h | 2088h | EDCH-Phys | Karri Ranta-aho (Nokia) | Rel-6 | TSG | MCC RAN | BB | Active | TS25.211, 25.212, 25.213, 25.214, 25.215 |  |  |  |  |
| 30 | 7.3 | FDD Enhanced Uplink - Layer 2 and 3 Protocol Aspects |  | 261d | 2004-03-15 A | 2005-03-14 A | 100% |  | 2004-03-15 | 2005-03-15 | 261d |  | finish no earlier than 2005-03-14 | R2 | 2088h | 2088h | EDCH-L23 | Joakim Bergström (Ericsson) | Rel-6 | TSG | MCC RAN | BB | Active | TS25.301, 25.302, 25.306, 25.321, 25.331 |  |  |  |  |
| 31 | 7.4 | FDD Enhanced Uplink - UTRAN Iub/Iur Protocol Aspects |  | 261d | 2004-03-15 A | 2005-03-14 A | 100% |  | 2004-03-15 | 2005-03-15 | 261d |  | finish no earlier than 2005-03-14 | R3 | 2088h | 2088h | EDCH-IurIub | Saso Stojanovski (Nortel) | Rel-6 | TSG | MCC RAN | BB | Active | TS25.401, 25.420, 25.423, 25.430, 25.433 |  |  |  |  |
| 32 | 7.5 | FDD Enhanced Uplink - RF Radio Transmission/ Reception, System Performance Requirements and Conformance Testing |  | 327d | 2004-03-15 A | 2005-06-15 | 35% | 212.55d | 2004-03-15 | 2005-06-15 | 327d | 516d | finish no earlier than 2005-06-15 | R4 | 2616h | 915.6h | EDCH-RF | Thomas Unshelm (Ericsson) | Rel-6 | TSG | MCC RAN | BB | Active | TS25.101, 25.104, 25.133, 25.141 | thomas.unshelm@ERICSSON.COM |  |  |  |
| 33 | 8 | **Rel-6 RAN improvements** |  | 656d? | 2002-09-09 A | 2005-03-15 | 88% | 79.05d? | 2002-09-09 | 2005-03-15 | 656d? | 209d |  | RP | 28312h | 22519.5h | RANimp |  | Rel-6 | TSG | Cesar |  |  |  |  |  |  |  |
| 34 | 9.2 | **RAB support enhancement** |  | 522d? | 2003-03-14 A | 2005-03-15 | 72% | 145.48d? | 2003-03-14 | 2005-03-15 | 522d? | 209d |  | R2 | 9360h | 6751.47h | RANimp-RABSE | Juha Mikola, Nokia | Rel-6 | TSG | MCC RAN | 624 |  | TR 25.862 | juha.mikola@nokia.com | BaAS |  |  |
| 35 | 8.1.1 | Iu enhancements for IMS support in RAN |  | 320d? | 2003-03-14 A | 2004-06-03 | 25% | 240d? | 2003-03-14 | 2004-06-03 | 320d? | 784d | start no earlier than 2003-03-14 | R3 | 2560h | 640h | RANimp-RABSE-IuEnhIMS | Phillipe Godin, Nortel | Rel-6 | TSG | MCC RAN |  |  |  | Philippe.Godin@nortelnetworks.com |  |  |  |
| 36 | 8.1.2 | Optimisation of downlink channelisation code utilisation |  | 262d | 2004-03-12 A | 2005-03-14 A | 100% |  | 2004-03-12 | 2005-03-15 | 262d |  | finish no earlier than 2005-03-14 | R1 | 2096h | 2096h | RANimp-RABSE-CodeOptFDD | Sarah Boumendil (Nortel Networks) | Rel-6 | TSG | MCC RAN | WT | Active |  | boumendi@nortelnetworks.com |  |  |  |
| 37 | 8.1.3 | Optimisation of channelisation code utilisation for 3.84 Mcps TDD |  | 261d | 2004-03-15 A | 2005-03-15 | 95% | 13.05d | 2004-03-15 | 2005-03-15 | 261d | 582d | finish no earlier than 2005-03-15 | R1 | 2088h | 1983.6h | RANimp-RABSE-CodOptTDD | Nicholas Anderson (IPWireless) | Rel-6 | TSG | MCC RAN | WT | Active |  |  |  |  |  |
| 38 | 8.1.4 | HS-DPCCH ACK/NACK Enhancement |  | 65d? | 2004-09-15 A | 2004-12-14 A | 100% |  | 2004-09-15 | 2004-12-15 | 65d? |  | finish no earlier than 2004-12-15 | R1 | 520h | 520h | RANimp-RABSE-ACKNACK | Jussi Kähtävä, Nokia | Rel-6 | TSG | MCC_RAN |  |  | TS25.212, TS25.214, TS24.331, TS25.433 |  |  |  |  |
| 39 | 8.1.5 | Deleted - Improvement of RRM across RNS and RNS/BSS | milestone | 0d? | 2003-12-05 A | 2003-12-05 A | 100% |  | 2003-12-05 | 2003-12-05 | 0d? |  | finish no earlier than 2003-12-05 | R3 |  |  | RANimp-RRM1 | Antti Toskala, Nokia | Rel-6 |  |  |  |  |  |  |  | RP-23 |  |
| 40 | 9.1 | Beamforming Enhancements |  | 66d | 2003-09-19 A | 2003-12-19 A | 100% |  | 2003-09-19 | 2003-12-19 | 66d |  | finish no earlier than 2004-03-12 | R1 | 528h | 528h | RANimp-BFE | Jussi Kähtävä, Nokia | Rel-6 | TSG | MCC_RAN |  |  | TS24.215, 25.423, 25.425, 25.433, 25.435 | jussi.kahtava@nokia.com |  |  |  |
| 41 | 8.3 | **Rel6 RRM optimization for Iur and Iub** |  | 126d | 2003-09-19 A | 2004-03-12 A | 100% |  | 2003-09-19 | 2004-03-12 | 126d |  |  | R3 | 2016h | 2016h | RANimp-RRMopt | Gert-Jan van Lieshout, Ericsson | Rel-6 | TSG | MCC_RAN |  |  |  | Gert-Jan.van.Lieshout@eln.ericsson.se | BaAS |  |  |
| 42 | 8.3.1 | Improved access to UE measurement data for CRNC to support TDD RRM |  | 126d | 2003-09-19 A | 2004-03-12 A | 100% |  | 2003-09-19 | 2004-03-12 | 126d |  | finish no earlier than 2004-03-15 | R3 | 1008h | 1008h | RANimp-RRMopt-UEMsD | Jim Miller, Interdigital | Rel-6 | TSG | MCC RAN | WT | Active | TS25.423 | jim.miller@interdigital.com |  | RP-22 |  |
| 43 | 8.4 | **Remote Control of Electrical Tilting Antennas** |  | 395d? | 2003-03-14 A | 2004-09-16 A | 100% |  | 2003-03-14 | 2004-09-16 | 395d? |  |  | R3 | 7464h | 7464h | RANimp-TiltAnt | Andreas Hauser, Vodafone | Rel-6 | TSG | MCC_RAN |  |  |  | Andreas.Hauser@vodafone.com |  |  |  |
| 44 | 8.4.1 | Tilting Antenna - RAN aspects |  | 393d? | 2003-03-14 A | 2004-09-14 A | 100% |  | 2003-03-14 | 2004-09-14 | 393d? |  | finish no earlier than 2004-09-14 | R3 | 3144h | 3144h | RANimp-TiltAnt | Andreas Hauser, Vodafone | Rel-6 | TSG | MCC_RAN |  |  | TS25.460, 25.461, 25.462, 25.463 | Andreas.Hauser@vodafone.com |  |  |  |
| 45 | 8.4.2 | OAM&P impacts |  | 145d | 2004-02-27 A | 2004-09-16 A | 100% |  | 2004-02-27 | 2004-09-16 | 145d |  | finish no earlier than 2004-09-16 | S5 | 1160h | 1160h | RANimp-TiltAnt-OAM | John MUDGE, Vodafone | Rel-6 | WG | Adrian |  |  | 32.804, 32.xyz | john.mudge@vodafone.co.uk |  |  | SP-24 |
| 46 | 8.5 | Network Assisted Cell Change (NACC) from UTRAN to GERAN - network-side aspects |  | 462d? | 2002-09-09 A | 2004-06-15 A | 100% |  | 2002-09-09 | 2004-06-15 | 462d? |  | finish no earlier than 2004-06-15 | R3 | 3696h | 3696h | RANimp-NACC | Brendan McWilliams, Vodafone | Rel-6 | TSG | MCC_RAN |  |  |  | Brendan.McWilliams@gb.vodafone.co.uk |  |  |  |
| 47 | 12 | **Location Services enhancements 2** |  | 1024d? | 2001-01-15 A | 2004-12-16 | 99% | 2.54d? | 2001-01-15 | 2004-12-16 | 1024d? | 271d |  | S2 | 77352h | 74168.1h | LCS2 |  | Rel-6 | TSG | Sang-Ui |  |  | 23.271 |  |  |  |  |
| 48 | 12.1 | **Improvement on Le interface** |  | 653d? | 2002-06-17 A | 2004-12-15 A | 100% |  | 2002-06-17 | 2004-12-15 | 653d? |  |  | S2 | 9872h | 9872h |  |  | Rel-6 | TSG |  |  |  |  |  |  |  |  |
| 49 | 9.1.1 | Stage 2 |  | 331d? | 2002-06-17 A | 2003-09-22 A | 100% |  | 2002-06-17 | 2003-09-22 | 331d? |  | start no earlier than 2002-06-17 | S2 | 2648h | 2648h |  |  | Rel-6 |  |  |  |  |  |  |  |  |  |
| 50 | 9.1.2 | Stage 3 - impacts MLP (Mobile Location Protocol) |  | 250d? | 2004-01-01 A | 2004-12-15 A | 100% |  | 2004-01-01 | 2004-12-15 | 250d? |  | finish no earlier than 2004-12-15 | OMA | 2000h | 2000h |  |  | Rel-6 |  |  |  |  |  | OMA-LIAISON@mail.openmobilealliance.org |  |  |  |

Notes:
- 33: Generic feature
- 34: This is a building block without particular end date
- 35: Closed RAN#24 due to the lack of progress
- 37: WIDS modified in RP#26, RP-040551
- 38: Approved at RP#25 as RP-040390
- 39: abandoned RP-23
- 44: Finished at RP#25
- 45: az: WID approved at SA5#37 (02/2004)
- 50: Updated according to SP-040232

| ID | WBS | Task | Type | Duration | Start | Finish | Complete | Remaining | Baseline start | Baseline finish | Baseline duration | Total slack | Constraint | Resources | Work | Actual work | Text6 | Text7 | Text5 | Text1 | Text8 | Text4 | Text9 | Text12 | Text2 |
| --- | --- | --- | --- | --- | --- | --- | --- | --- | --- | --- | --- | --- | --- | --- | --- | --- | --- | --- | --- | --- | --- | --- | --- | --- | --- |
| 51 | 12.2 | **Enhanced support for anonymity and user privacy** |  | 638d? | 2002-07-08 A | 2004-12-15 A | 100% |  | 2002-07-08 | 2004-12-15 | 638d? |  |  | S2 | 9144h | 9144h | Rel-6 | TSG |  |  |  |  |  |  |  |
| 52 | 9.2.1 | Stage 2 |  | 255d? | 2002-07-08 A | 2003-06-27 A | 100% |  | 2002-07-08 | 2003-06-27 | 255d? |  | finish no earlier than 2003-06-27 | S2 | 2040h | 2040h | Rel-6 |  |  |  |  |  |  |  |  |
| 53 | 9.2.2 | Stage 3 - impacts MLP and RLP |  | 250d? | 2004-01-01 A | 2004-12-15 A | 100% |  | 2004-01-01 | 2004-12-15 | 250d? |  | finish no earlier than 2004-12-15 | OMA | 2000h | 2000h | Rel-6 |  | OMA-LIAISON@mail.openmobilealliance.org |  |  |  |  |  |  |
| 54 | 12.3 | **Enhanced inter-GMLC interface** |  | 648d? | 2002-06-24 A | 2004-12-15 A | 100% |  | 2002-06-24 | 2004-12-15 | 648d? |  |  | S2 | 9704h | 9704h | Rel-6 | TSG |  |  |  |  |  |  |  |
| 55 | 9.3.1 | Stage 2 |  | 315d? | 2002-06-24 A | 2003-09-05 A | 100% |  | 2002-06-24 | 2003-09-05 | 315d? |  | finish no earlier than 2003-09-05 | S2 | 2520h | 2520h | Rel-6 |  |  |  |  |  |  |  |  |
| 56 | 9.3.2 | Stage 3 - definition of RLP and PCP |  | 250d? | 2004-01-01 A | 2004-12-15 A | 100% |  | 2004-01-01 | 2004-12-15 | 250d? |  | finish no earlier than 2004-12-15 | OMA | 2000h | 2000h | Rel-6 |  | OMA-LIAISON@mail.openmobilealliance.org |  |  |  |  |  |  |
| 57 | 12.4 | **Location Services support for IMS public identities** |  | 473d? | 2003-02-24 A | 2004-12-15 A | 100% |  | 2003-02-24 | 2004-12-15 | 473d? |  |  | S2 | 7704h | 7704h | Rel-6 | TSG |  |  |  |  |  |  |  |
| 58 | 9.4.1 | Stage 2 |  | 240d? | 2003-02-24 A | 2004-01-23 A | 100% |  | 2003-02-24 | 2004-01-23 | 240d? |  | finish no earlier than 2004-01-23 | S2 | 1920h | 1920h | Rel-6 |  |  |  |  |  |  |  |  |
| 59 | 9.4.2 | Stage 3 - impacts MLP, RLP and PCP |  | 250d? | 2004-01-01 A | 2004-12-15 A | 100% |  | 2004-01-01 | 2004-12-15 | 250d? |  | finish no earlier than 2004-12-15 | OMA | 2000h | 2000h | Rel-6 |  | OMA-LIAISON@mail.openmobilealliance.org |  |  |  |  |  |  |
| 60 | 12.5 | **New area event for location service triggering reports** |  | 663d? | 2002-06-03 A | 2004-12-15 | 98% | 10.15d? | 2002-06-03 | 2004-12-15 | 663d? | 272d |  | S2 | 11416h | 8250.43h | Rel-6 | TSG |  |  |  |  |  |  |  |
| 61 | 9.5.1 | Stage 2 |  | 280d? | 2002-06-03 A | 2003-06-27 A | 100% |  | 2002-06-03 | 2003-06-27 | 280d? |  | finish no earlier than 2003-06-27 | S2 | 2240h | 2240h | Rel-6 |  |  |  |  |  |  |  |  |
| 62 | 9.5.2 | Stage 3 for UE-CN signalling |  | 234d? | 2003-10-09 A | 2004-08-31 | 95% | 11.7d? | 2003-10-09 | 2004-08-31 | 234d? | 721d | start no earlier than 2003-10-09 | N4 | 1872h | 1778.4h | Rel-6 |  |  |  |  |  |  |  |  |
| 63 | 9.5.3 | Stage 3 - impacts MLP, RLP and PCP |  | 250d? | 2004-01-01 A | 2004-12-15 A | 100% |  | 2004-01-01 | 2004-12-15 | 250d? |  | finish no earlier than 2004-12-15 | OMA | 2000h | 2000h | Rel-6 |  | OMA-LIAISON@mail.openmobilealliance.org |  |  |  |  |  |  |
| 64 | 12.7 | **UE positioning** |  | 957d? | 2001-01-15 A | 2004-09-14 A | 100% |  | 2001-01-15 | 2004-09-14 | 957d? |  |  | RP | 18480h | 18480h | Rel-6 | TSG |  | LCS2-UEpos | MCC_RAN |  |  |  |  |
| 65 | 12.8 | Open SMLC-SRNC Interface within the UTRAN to support UTRAN Rel4 positioning methods |  | 700d? | 2001-01-15 A | 2003-09-19 A | 100% |  | 2001-01-15 | 2003-09-19 | 700d? |  | finish no earlier than 2003-09-19 | R2 | 5600h | 5600h | Rel-6 | TSG | Meik.Kottkamp@siemens.com | LCS-Rel4Pos |  | Meik Kottkamp, Siemens | 2475 |  |  |
| 66 | 9.6.2 | A-GPS minimum performance specification |  | 333d? | 2003-06-06 A | 2004-09-14 A | 100% |  | 2003-06-06 | 2004-09-14 | 333d? |  | finish no earlier than 2004-09-14 | R4 | 2664h | 2664h | Rel-6 | TSG | donglin.shen@attws.com | LCS-UEPos-AGPSPerf | MCC_RAN | Donglin Shen, AT&T Wireless Services |  |  |  |
| 67 | 12.7.2 | FS on Enhancements to OTDOA Positioning using advanced blanking methods |  | 320d | 2002-07-01 A | 2003-09-19 A | 100% |  | 2002-07-01 | 2003-09-19 | 320d |  | finish no earlier than 2003-09-19 | R2 | 2560h | 2560h | Rel-6 | TSG | david.bartlett@cursor-system.com | LCS2-UEpos-FSBlank |  | David Bartlett, Cambridge Positioning Systems |  |  |  |
| 68 | 9.6.4 | Deleted - UE positioning enhancements - other methods | milestone | 0d? | 2003-09-26 A | 2003-09-26 A | 100% |  | 2003-09-26 | 2003-09-26 | 0d? |  | finish no earlier than 2003-09-26 | R2 |  |  | Rel-6 |  |  | LCS2-UEpos-enh |  | Meik Kottkamp, Siemens |  | RP-24 |  |
| 69 | 9.7 | LCS charging |  | 455d? | 2003-03-21 A | 2004-12-16 A | 100% |  | 2003-03-21 | 2004-12-16 | 455d? |  | start no earlier than 2003-03-21 | S5 | 3640h | 3640h | Rel-6 | TSG |  | LCS2-CH |  |  |  |  |  |
| 70 | 14 | **Rel-6 Security enhancements** |  | 1018d? | 2001-01-03 A | 2004-11-26 | 75% | 250.03d? | 2001-01-03 | 2004-11-26 | 1018d? | 285d |  | S3 | 28824h | 20775.7h | Rel-6 | TSG | Peter.Howard@vodafone.com | SEC1 | Maurice | Peter Howard, Vodafone |  |  |  |
| 71 | 14.1 | **Enhanced HE control of security (including positive authentication reporting)** |  | 712d | 2001-01-03 A | 2003-09-25 | 47% | 378d | 2001-01-03 | 2003-09-25 | 712d | 591d |  | S3 | 14064h | 8016h | Rel-6 |  | Peter.Howard@vodafone.com |  |  | Peter Howard, Vodafone | 2026 |  |  |
| 72 | 14.1.1 | Stage 2 |  | 378d | 2001-01-03 | 2002-06-14 |  |  | 2001-01-03 | 2002-06-14 | 378d | 1298d | finish no earlier than 2002-06-14 | S3 | 3024h |  | Rel-6 |  |  |  |  |  | 2027 |  |  |
| 73 | 14.1.3 | **Network domain security** |  | 334d | 2002-06-17 A | 2003-09-25 A | 100% |  | 2002-06-17 | 2003-09-25 | 334d |  |  | S3 | 5344h | 5344h | Rel-6 | TSG | Geir-myrdahl.koien@telenor.com | SEC1-NDS |  | Geir M. Køien, Telenor |  |  | Sec |
| 74 | 14.1.3.1 | IP network layer security (NDS/IP) |  | 334d | 2002-06-17 A | 2003-09-25 A | 100% |  | 2002-06-17 | 2003-09-25 | 334d |  | finish no earlier than 2003-09-25 | S3 | 2672h | 2672h | Rel-6 | WG |  | SEC1-NDS-IP |  |  |  |  |  |
| 75 | 10.2 | Network Domain Security; Authentication Framework (NDS/AF) |  | 521d? | 2002-02-15 A | 2004-02-13 A | 100% |  | 2002-02-15 | 2004-02-13 | 521d? |  | finish no earlier than 2004-02-13 | S3 | 4168h | 4168h | Rel-6 | TSG | tommi.viitanen@nokia.com | SEC1-NDS-AF |  | Tommi Viitanen, Nokia |  |  |  |
| 76 | 10.3 | Key Management of group keys for Voice Group Call Services |  | 306d | 2003-09-26 A | 2004-11-26 A | 100% |  | 2003-09-26 | 2004-11-26 | 306d |  | finish no earlier than 2004-11-26 | S3 | 2448h | 2448h | Rel-6 | TSG | benno.tietz@vodafone.com | SECGKYV | Maurice | Benno Tietz, Vodafone D2 |  |  |  |

Notes:
- 53: Updated according to SP-040232
- 56: Updated according to SP-040232
- 59: Updated according to SP-040232
- 62: 31/10/2003 work has started. Current stage 3 fullfills the requirements of stage 2. ......
- 63: Updated according to SP-040232
- 65: Text3: TS25.305, 25.401, 25.450, 25.452, 25.453
- 66: Finished at RP#25 / Text3: TS25.171
- 68: This is a building block without particular end date
- 69: SA#26 12/2004 completed / Text3: 32.271
- 70: Added BB UE authentication and rapporteur added.
- 71: Added by SP-000575 without any dates. 18/10/00: Change of WI title, added hyperlink rapporteur new end date 03/01. New end date and correct Release to be decided S3#18
- 72: New end date and correct Release to be decided S3#18
- 73: WID approved for Rel-6 at SA#17. Completed 2004-12
- 74: Should be complete after SA3#27. Completed 2004-12 / Text3: TS 33.210
- 75: WID approved SA#19. Work started after FS approved SA#18
- 76: Approved TSG#21. Completed 2004-12 / Text3: 42.068, 43.068, 44.068, 42.069, 43.069, 44.069, 31.102, 24.008, 48.008, 42.009, 43.020

| ID | WBS | Task | Type | Duration | Start | Finish | Complete | Remaining | Baseline start | Baseline finish | Baseline duration | Total slack | Constraint | Resources | Work | Actual work | Text1 | Text3 | Text6 | Text7 | Text8 | Text4 | Text5 | Text2 | Text9 | Text12 |
| --- | --- | --- | --- | --- | --- | --- | --- | --- | --- | --- | --- | --- | --- | --- | --- | --- | --- | --- | --- | --- | --- | --- | --- | --- | --- | --- |
| 77 | 16 | **IMS Phase 2** |  | 1395d? | 2000-08-28 A | 2005-12-30 | 98% | 32.57d? | 2000-08-28 | 2009-11-05 | 2399d? | 0d |  | S1 | 126048h | 116263h | IMS2 | 23.228 | Rel-6 | TSG | Sang-Ui |  |  |  |  |  |
| 78 | 11.1 | Enhancements to the Cx and Sh interfaces |  | 323d? | 2003-06-06 A | 2004-08-31 | 95% | 16.15d? | 2003-06-06 | 2004-08-31 | 323d? | 721d | finish no earlier than 2004-08-31 | N4 | 2584h | 2454.8h | IMS2-CCR |  | Rel-6 | WG |  |  |  |  |  |  |
| 79 | 16.12 | **IMS Group Management** |  | 715d? | 2002-03-14 A | 2004-12-08 A | 100% |  | 2002-03-14 | 2004-12-08 | 715d? |  |  | S1 | 12680h | 12680h | IMSGM |  | Rel-6 | TSG |  | Juha Kalliokulju (Nokia) | juha.kalliokulju@nokia.com |  |  |  |
| 80 | 16.12.1 | Stage 1 - TS on IMS group management |  | 193d | 2002-03-14 A | 2002-12-09 A | 100% |  | 2002-03-14 | 2002-12-09 | 193d |  | finish no earlier than 2002-12-09 | S1 | 1544h | 1544h |  |  | Rel-6 | TSG |  | Juha Kalliokulju (Nokia) | juha.kalliokulju@nokia.com |  |  |  |
| 81 | 11.2.2 | Stage 2 |  | 158d? | 2003-05-26 A | 2003-12-31 A | 100% |  | 2003-05-26 | 2003-12-31 | 158d? |  | finish no earlier than 2003-12-31 | S2 | 1264h | 1264h |  |  | Rel-6 |  |  |  |  |  |  |  |
| 82 | 11.2.3 | Stage 3 for IMS Group management (e.g. chat) |  | 519d? | 2002-12-13 A | 2004-12-08 A | 100% |  | 2002-12-13 | 2004-12-08 | 519d? |  | finish no earlier than 2004-12-08 | N1 | 4152h | 4152h |  |  | Rel-6 |  |  | Keith Drage, Lucent | drage@lucent.com |  |  |  |
| 83 | 11.3 | **IMS Conferencing** |  | 548d? | 2002-11-04 A | 2004-12-08 A | 100% |  | 2002-11-04 | 2004-12-08 | 548d? |  |  | N1 | 10960h | 10960h |  |  | Rel-6 |  |  |  |  |  |  |  |
| 84 | 11.3.1 | Stage 2 |  | 303d? | 2002-11-04 A | 2003-12-31 A | 100% |  | 2002-11-04 | 2003-12-31 | 303d? |  | finish no earlier than 2003-12-31 | S2 | 2424h | 2424h |  |  | Rel-6 |  |  |  |  |  |  |  |
| 85 | 11.3.2 | Stage 3 |  | 519d? | 2002-12-13 A | 2004-12-08 A | 100% |  | 2002-12-13 | 2004-12-08 | 519d? |  | finish no earlier than 2004-12-08 | N1 | 4152h | 4152h |  |  | Rel-6 |  |  | Keith Drage, Lucent | drage@lucent.com |  |  |  |
| 86 | 16.11 | **IMS Messaging** |  | 992d? | 2002-03-14 A | 2005-12-30 | 90% | 96.87d? | 2002-03-14 | 2005-06-30 | 861d? | 0d |  | S1 | 23912h | 21577.1h | IMSM |  | Rel-6 | TSG |  | Juha Kalliokulju (Nokia) | juha.kalliokulju@nokia.com |  |  |  |
| 87 | 16.11.1 | TR on support of messaging in the IMS |  | 193d | 2002-03-14 A | 2002-12-09 A | 100% |  | 2002-03-14 | 2002-12-09 | 193d |  | finish no earlier than 2002-12-09 | S1 | 1544h | 1544h | IMSM-TR |  | Rel-6 | TSG |  | Juha Kalliokulju (Nokia) | juha.kalliokulju@nokia.com |  |  |  |
| 88 | 11.4.2 | Stage 1 22.340 |  | 23d? | 2002-11-11 A | 2002-12-11 A | 100% |  | 2002-11-11 | 2002-12-11 | 23d? |  | finish no earlier than 2002-12-11 | S1 | 184h | 184h | IMSM-TS | 22.340 | Rel-6 | TSG |  | Juha Kalliokulju (Nokia) | juha.kalliokulju@nokia.com |  |  |  |
| 89 | 11.4.3 | CRs to 22.140 & 22.228 |  | 263d? | 2002-03-14 A | 2003-03-17 A | 100% |  | 2002-03-14 | 2003-03-17 | 263d? |  | finish no earlier than 2003-03-17 | S1 | 2104h | 2104h | IMSM-CR | 22.140,22.228 | Rel-6 | TSG |  | Juha Kalliokulju (Nokia) | juha.kalliokulju@nokia.com |  |  |  |
| 90 | 16.11.3 | Stage 2 |  | 477d | 2002-11-04 A | 2004-08-31 A | 100% |  | 2002-11-04 | 2004-08-31 | 477d |  | finish no earlier than 2004-08-31 | S2 | 3816h | 3816h |  |  | Rel-6 |  |  |  |  |  |  |  |
| 91 | 11.4.5 | Stage 3 for IMS Messaging |  | 519d? | 2002-12-13 A | 2004-12-08 A | 100% |  | 2002-12-13 | 2004-12-08 | 519d? |  | finish no earlier than 2004-12-08 | N1 | 4152h | 4152h |  |  | Rel-6 |  |  | Keith Drage, Lucent | drage@lucent.com |  |  |  |
| 92 | 11.4.6 | SIP/SIMPLE Instant messaging |  | 522d? | 2004-01-01 A | 2005-12-30 | 63% | 195d? | 2004-01-01 | 2005-06-30 | 391d? | 0d | finish no earlier than 2005-06-30 | OMA | 4176h | 2616h |  |  | Rel-6 | n/a |  |  | OMA-LIAISON@mail.openmobilealliance.org |  |  |  |
| 93 | 11.5 | **Additional SIP Capabilities support not covered by Rel-5** |  | 680d? | 2002-11-11 A | 2005-06-17 A | 100% |  | 2002-11-11 | 2004-09-08 | 478d? |  |  | N1 | 13392h | 13392h |  |  | Rel-6 |  |  |  |  |  |  |  |
| 94 | 11.5.1 | Stage 2 for add SIP cap (e.g. forking) |  | 335d? | 2002-11-11 A | 2004-02-20 A | 100% |  | 2002-11-11 | 2004-02-20 | 335d? |  | finish no earlier than 2004-02-20 | S2 | 2680h | 2680h |  |  | Rel-6 |  |  |  |  |  |  |  |
| 95 | 11.5.2 | Stage 3 for Additional SIP Capabilities |  | 454d? | 2002-12-13 A | 2004-09-08 A | 100% |  | 2002-12-13 | 2004-09-08 | 454d? |  | finish no earlier than 2004-09-08 | N1 | 3632h | 3632h |  |  | Rel-6 |  |  | Keith Drage, Lucent | drage@lucent.com |  |  |  |
| 96 | 11.5.3 | Procedured associated with IMS-ALG |  | 205d? | 2004-09-06 A | 2005-06-17 A | 100% |  |  |  |  |  | start no earlier than 2004-09-06 | N1 | 1640h | 1640h |  |  | Rel-6 |  |  |  |  |  |  |  |
| 97 | 11.6 | Review additional SIP Capabilities against IMS |  | 454d? | 2002-12-13 A | 2004-09-08 A | 100% |  | 2002-12-13 | 2004-09-08 | 454d? |  | finish no earlier than 2004-09-08 | N1 | 3632h | 3632h |  |  | Rel-6 |  |  | Keith Drage, Lucent | drage@lucent.com |  |  |  |
| 98 | 16.5 | **Interworking between IMS and IP networks** |  | 1118d? | 2000-08-28 A | 2004-12-08 | 99% | 0d? | 2000-08-28 | 2004-12-08 | 1118d? | 0d |  | N3 | 31712h | 24888h | IMS-CCR-IWIP | 23.821, 29.061, 29.162 | Rel-6 | TSG |  | Nigel Holland, BT | nigel.holland@bt.com | BaAS | 2048 |  |
| 99 | 16.5.1 | Interworking for 3GPP_SIP and IETF_SIP |  | 730d | 2000-08-28 A | 2003-06-13 A | 100% |  | 2000-08-28 | 2003-06-13 | 730d |  | finish no earlier than 2003-06-13 | N3 | 5840h | 5840h |  | New TR 29.962 | Rel-6 |  |  | Thomas Belling, Siemens |  |  |  |  |
| 100 | 16.5.2 | Interworking for IPv6 to IPv4 |  | 1118d | 2000-08-28 A | 2004-12-08 A | 100% |  | 2000-08-28 | 2004-12-08 | 1118d |  | finish no earlier than 2004-12-08 | N3 | 8944h | 8944h |  | 29.163 | Rel-6 |  |  |  |  |  |  |  |
| 101 | 11.7.3 | Interworking for IPv6 to IPv4 (SIP / SDP aspects) |  | 87d? | 2004-05-11 A | 2004-09-08 A | 100% |  | 2004-05-11 | 2004-09-08 | 87d? |  | finish no earlier than 2004-09-08 | N1 | 696h | 696h |  |  | Rel-6 |  |  |  |  |  |  |  |
| 102 | 16.8.1 | stage 3 of interworking with non-IMS IP networks |  | 911d | 2001-03-14 A | 2004-09-08 A | 100% |  | 2001-03-14 | 2004-09-08 | 911d |  | finish no earlier than 2004-09-08 | N1 | 7288h | 7288h |  |  | Rel-6 |  |  |  |  |  |  |  |
| 103 | 16.6.1 | Interworking between IMS and CS networks |  | 929d? | 2000-08-28 A | 2004-03-18 A | 100% |  | 2000-08-28 | 2004-03-18 | 929d? |  | finish no earlier than 2004-03-18 | N3 | 7432h | 7432h | IMS-CCR-IWCS | 29.163, 29.061, 24.228, and new CN4 specification | Rel-6 | TSG |  | Brendan Mc Williams, Vodafone | brendan.mcwilliams@vf.vodafone.co.uk | CCaR |  |  |
| 104 | 16.10 | Mn interface (IM-MGW to MGCF) enhancements (CN4 Part) |  | 418d | 2001-08-07 A | 2004-09-01 | 90% | 41.8d | 2001-08-07 | 2004-09-01 | 418d | 347d | finish no earlier than 2004-09-01 | N4 | 3344h | 3009.6h | IMS2-Mn |  | Rel-6 |  |  |  |  |  |  |  |
| 105 | 11.10 | Study of subscriber and operators relationship in IMS and related ISIM requirements for Rel 6” |  | 20d? | 2002-11-15 A | 2002-12-12 A | 100% |  | 2002-11-15 | 2002-12-12 | 20d? |  | finish no earlier than 2002-12-12 | S1 | 160h | 160h |  |  | Rel-6 |  |  | Juha Kalliokulju (Nokia) | juha.kalliokulju@nokia.com |  |  |  |
| 106 | 11.11 | Lawful Interception in the 3GPP Rel-6 architecture |  | 269d? | 2002-12-09 A | 2003-12-18 A | 100% |  | 2002-12-09 | 2003-12-18 | 269d? |  | finish no earlier than 2003-12-18 | S3 | 2152h | 2152h | SEC1-LI | 33.106, 33.107, 33.108 | Rel-6 | TSG |  | Berthold Wilhelm | Berthold.Wilhelm@REGTP.DE |  |  |  |
| 107 | 11.12 | IMS Subscription and access scenarios |  | 130d? | 2002-12-16 A | 2003-06-13 A | 100% |  | 2002-12-16 | 2003-06-13 | 130d? |  | start no earlier than 2002-12-16 | S1 | 1040h | 1040h |  | 22.800 | Rel-6 |  |  |  |  |  |  |  |
| 108 | 11.13 | IMS charging |  | 455d? | 2003-03-21 A | 2004-12-16 A | 100% |  | 2003-03-21 | 2004-12-16 | 455d? |  | finish no earlier than 2004-12-16 | S5 | 3640h | 3640h | IMS2-CH | 32.260 | Rel-6 | TSG |  |  |  |  |  |  |
| 109 | 11.14 | IMS Management objects |  | 306d? | 2004-09-03 A | 2005-11-05 A | 100% |  | 2004-09-03 | 2009-11-05 | 1350d? |  | finish no earlier than 2005-03-04 | N1 | 2448h | 2448h |  | TS 24.167 | Rel-6 | WG |  |  |  |  |  |  |
| 110 | 11.15 | Deleted - Stage 2 of IMS Phase 2 | milestone | 0d? | 2003-09-19 A | 2003-09-19 A | 100% |  | 2003-09-19 | 2003-09-19 | 0d? |  | finish no earlier than 2003-09-19 | S2 |  |  |  |  | Rel-6 |  |  |  |  |  |  | SP-24 |

Notes:
- 77: Not yet available: verbally approved at SA15, actual WID to be provided at SA16 by Lucent
- 78: Shared public user identities need to be solved. If email approval CR is accepted. Work 100% done....
- 82: Depends on CN decision on CPCP in Rel-6. Complete, if unresolved IETF dependencies are dropped (-> LS to CN plenary)
- 85: Depends on CN decision on IETF dependencies in Rel-6. Higher figure if CPCP is dropped (-> LS to CN plenary)
- 92: Updated according to SP-040232
- 98: [DAB 14.02.02] - end date pushed back to March 2003
- 99: [DAB - 20.08.03] - CN Part of TR Complete @ CN#20
- 103: [DAB - 25.05.04] - CN3 consider this work to be complete
- 104: TISPAN issue is open
- 108: SA#26 12/2004 completed

| ID | WBS | Task | Type | Duration | Start | Finish | Complete | Remaining | Baseline start | Baseline finish | Baseline duration | Total slack | Constraint | Resources | Work | Actual work | Text1 | Text3 | Text4 | Text6 | Text7 | Text8 | Text10 | Text5 | Text2 | Text9 |
| --- | --- | --- | --- | --- | --- | --- | --- | --- | --- | --- | --- | --- | --- | --- | --- | --- | --- | --- | --- | --- | --- | --- | --- | --- | --- | --- |
| 111 | 12 | **3GPP Enablers for services like Push to Talk over Cellular (PoC)** |  | 459d? | 2003-09-08 A | 2005-06-09 | 97% | 14.43d? | 2003-09-08 | 2005-06-09 | 459d? | 146d |  | S2 | 10696h | 10359.8h | PoC | 23.979 | Shabnam Sultana, Ericsson | Rel-6 | TSG | Sang-Ui |  |  |  |  |
| 112 | 12.1 | Feasibility Study |  | 322d? | 2003-09-08 A | 2004-11-30 A | 100% |  | 2003-09-08 | 2004-11-30 | 322d? |  | finish no earlier than 2004-11-30 | S2 | 2576h | 2576h | PoC | 23.979 | Shabnam Sultana, Ericsson | Rel-6 |  |  | SP-24 |  |  |  |
| 113 | 12.2 | Dependencies on OMA PoC |  | 303d? | 2004-01-01 A | 2005-02-28 A | 100% |  | 2004-01-01 | 2004-12-30 | 261d? |  | finish no earlier than 2004-12-30 | OMA | 2424h | 2424h | PoC |  |  | Rel-6 | n/a |  | SP-24 | OMA-LIAISON@mail.openmobilealliance.org |  |  |
| 114 | 12.3 | Selection of one or more PoC codec(s) for PoC |  | 69d? | 2004-09-13 A | 2004-12-16 A | 100% |  | 2004-09-13 | 2004-12-16 | 69d? |  | start no earlier than 2004-09-13 | S4 | 552h | 552h | PoC | 26.235, 26.236 |  | Rel-6 | TSG | Paolo | SP-25 |  |  |  |
| 115 | 12.4 | PoC charging |  | 184d? | 2004-09-27 A | 2005-06-09 | 85% | 27.6d? | 2004-09-27 | 2005-06-09 | 184d? | 146d | finish no earlier than 2005-06-09 | S5 | 1472h | 1251.2h | PoC-CH | 32.272 |  | Rel-6 | TSG |  |  |  |  |  |
| 116 | 13 | Interworking aspects and migration scenarios for IPv4 based IMS Implementations (Study) |  | 210d? | 2003-09-08 A | 2004-06-25 A | 100% |  | 2003-09-08 | 2004-06-25 | 210d? |  | finish no earlier than 2004-06-25 | S2 | 1680h | 1680h | IPv4IMS | 23.881 | Alexander Milinski, Siemens | Rel-6 |  | Sang-Ui |  |  |  |  |
| 117 | 16.3 | **Interoperability and Commonality between IMS using different "IP-connectivity Networks"** |  | 325d? | 2002-09-16 A | 2003-12-12 A | 100% |  | 2002-09-16 | 2003-12-12 | 325d? |  |  | S2 | 9176h | 9176h | IMSCOOP | 23.864 |  | Rel-6 | TSG | Sang-Ui |  |  |  |  |
| 118 | 16.3.1 | Stage 2 for Interoperability |  | 272d | 2002-09-16 A | 2003-09-30 A | 100% |  | 2002-09-16 | 2003-09-30 | 272d |  | finish no earlier than 2003-09-30 | S2 | 2176h | 2176h |  | 23.864 | Balazs Beternyi, Nokia | Rel-6 |  |  |  |  |  |  |
| 119 | 14.2 | Stage 2 for commonality |  | 265d? | 2002-09-16 A | 2003-09-19 A | 100% |  | 2002-09-16 | 2003-09-19 | 265d? |  | start no earlier than 2002-09-16 | S2 | 2120h | 2120h |  | 23.864 | Balazs Beternyi, Nokia | Rel-6 |  |  |  |  |  |  |
| 120 | 16.3.2 | Stage 3 |  | 305d | 2002-10-14 A | 2003-12-12 A | 100% |  | 2002-10-14 | 2003-12-12 | 305d |  | finish no earlier than 2003-12-12 | N1 | 2440h | 2440h |  |  | Keith Drage, Lucent | Rel-6 |  |  |  | drage@lucent.com |  |  |
| 121 | 17 | **Support of Push Services** |  | 823d | 2001-01-03 A | 2004-02-27 A | 100% |  | 2001-01-03 | 2004-02-27 | 823d |  |  | S1 | 11390.6h | 11390.6h | PUSH | 23.976 | Yoshinori Kitada, NTT Comware | Rel-6 | TSG | Sang-Ui |  |  | CCaR | 1365 |
| 122 | 17.1 | Stage 1 |  | 378d | 2001-01-03 A | 2002-06-14 A | 100% |  | 2001-01-03 | 2002-06-14 | 378d |  | finish no earlier than 2002-06-14 | S1 | 3024h | 3024h |  |  |  | Rel-6 |  |  |  |  |  |  |
| 123 | 17.3 | TR 23.976 on Push Architecture |  | 340d | 2002-11-11 A | 2004-02-27 A | 100% |  | 2002-11-11 | 2004-02-27 | 340d |  | finish no earlier than 2004-02-27 | S2 | 2720h | 2720h |  | 23.976 | Nick Alfano, RIM | Rel-6 |  |  |  |  |  |  |
| 124 | 18 | **Multimedia Messaging (MMS) enhancements** |  | 735d? | 2002-08-15 A | 2005-06-08 | 98% | 15.64d? | 2002-08-15 | 2005-03-17 | 676d? | 147d |  | T2 | 29856h | 29269.2h | MMS6 |  | Josef Laumen, Siemens | Rel-6 | TSG | Friedhelm |  | Josef.Laumen@SAL.SIEMENS.DE | Mes |  |
| 125 | 18.1 | **Definition of service requirements** |  | 286d? | 2002-11-15 A | 2003-12-19 A | 100% |  | 2002-11-15 | 2003-12-19 | 286d? |  |  | S1 | 4576h | 4576h | MMS6-SR | 22.140 |  | Rel-6 |  |  |  |  |  |  |
| 126 | 16.1.1 | Definition of service requirements charging |  | 286d? | 2002-11-15 A | 2003-12-19 A | 100% |  | 2002-11-15 | 2003-12-19 | 286d? |  | finish no earlier than 2003-12-20 | S1 | 2288h | 2288h |  | 22.140 | Josef Laumen, Siemens | Rel-6 |  |  |  | Josef.Laumen@SAL.SIEMENS.DE |  |  |
| 127 | 18.2 | Technical realization |  | 591d | 2002-09-06 A | 2004-12-10 A | 100% |  | 2002-09-06 | 2004-12-10 | 591d |  | finish no earlier than 2004-12-10 | T2 | 4728h | 4728h |  | 23.140 | Josef Laumen, Siemens | Rel-6 | TSG | Friedhelm |  | Josef.Laumen@SAL.SIEMENS.DE |  |  |
| 128 | 18.3 | OMA dependencies |  | 446d | 2003-08-15 A | 2005-04-29 | 90% | 43d | 2003-08-15 | 2004-12-10 | 346d | 175d | finish no earlier than 2004-12-10 | OMA | 3568h | 3224h |  | OMA specs |  | Rel-6 | n/a | Friedhelm |  |  |  |  |
| 129 | 18.4 | MMS formats and codecs |  | 735d | 2002-08-15 A | 2005-06-08 | 98% | 14.7d | 2002-08-15 | 2005-03-17 | 676d | 147d | finish no earlier than 2005-06-08 | S4 | 5880h | 5762.4h | MMS6-Codec | 26.140, 26.936 | Roberto Castagno (Nokia) | Rel-6 |  | Paolo |  | roberto.castagno@nokia.com |  |  |
| 130 | 16.5 | Handling of private addressing schemes in MMS |  | 263d | 2003-12-10 A | 2004-12-10 A | 100% |  | 2003-12-10 | 2004-12-10 | 263d |  | finish no earlier than 2004-12-10 | T2 | 2104h | 2104h |  | 23.140 | Steffen Habermann, T-Mobile | Rel-6 | TSG | Friedhelm |  | Steffen.Habermann@T-MOBILE.DE |  |  |
| 131 | 16.6 | Deleted - FS Multiple MMS Relay/Server Architecture | milestone | 0d | 2004-12-10 A | 2004-12-10 A | 100% |  | 2004-12-10 | 2004-12-10 | 0d |  | finish no earlier than 2004-12-10 | T2 |  |  |  | probably Annex to 23.140 | Juan Gorospe, Telefónica Móviles | Rel-6 | TSG | Friedhelm |  | gorospe_j@tsm.es |  |  |
| 132 | 16.7 | MMS charging |  | 390d? | 2003-03-21 A | 2004-09-16 A | 100% |  | 2003-03-21 | 2004-09-16 | 390d? |  | start no earlier than 2003-03-21 | S5 | 3120h | 3120h | MMS6-CH | 32.270 |  | Rel-6 | TSG |  |  |  |  |  |
| 133 | 19 | **Rel-6 MExE enhancements** |  | 326d | 2002-03-08 A | 2003-06-06 A | 100% |  | 2002-03-08 | 2003-06-06 | 326d |  |  | T2 | 7328h | 7328h | MEXE6 |  |  | Rel-6 | TSG | Friedhelm |  |  | Ter |  |
| 134 | 19.1 | MExE Rel-6 Improvements and Investigations |  | 264d | 2002-03-08 A | 2003-03-12 A | 100% |  | 2002-03-08 | 2003-03-12 | 264d |  | finish no earlier than 2003-03-12 | T2 | 2112h | 2112h | MEXE6-ENHANC | 22.057, 23.057 | Lars Brenk (TTPCom) | Rel-6 | TSG |  |  | lsb_ttpcom@HOTMAIL.COM | Ter |  |
| 135 | 19.2 | MExE Run-Time Independent Framework Feasibility Study |  | 326d | 2002-03-08 A | 2003-06-06 A | 100% |  | 2002-03-08 | 2003-06-06 | 326d |  | finish no earlier than 2003-06-06 | T2 | 2608h | 2608h | MEXE6-RTIF | 22.857 | Aaron Cohen (Intel) | Rel-6 | TSG |  |  | Aaron.Cohen@intel.com | Ter |  |
| 136 | 21 | Subscription Management |  | 650d | 2002-09-20 A | 2005-03-17 A | 100% |  | 2002-09-20 | 2005-03-17 | 650d |  | finish no earlier than 2005-03-17 | S5 | 5200h | 5200h | SuM | 32.140/1, 32.171/2/5, 32.803 | Istvan ABA (T-Mobile Austria) | Rel-6 | TSG | Adrian |  | istvan.aba@t-mobile.at |  |  |

Notes:
- 113: Updated according to SP-040232
- 114: Completed
- 115: SA#27: Dedicated WT WID
- 118: No contributions assumed that no more will be done in 3GPP hence work may need to be done in 3GPP2
- 121: AS: Changed from FS to actual support of Push
- 129: TR tbc by Sept. 05
- 131: originally it was intended to create a FS TR but most likely the work will become an Annex of 23.140
- 132: SA#25 09/2004 completed
- 136: TSG#26: Updated WID SP-040763 was SP-020448

| ID | WBS | Task | Duration | Start | Finish | Complete | Remaining | Baseline start | Baseline finish | Baseline duration | Total slack | Constraint | Resources | Work | Actual work | Text1 | Text4 | Text6 | Text7 | Text8 | Text9 | Text3 | Text5 |
| --- | --- | --- | --- | --- | --- | --- | --- | --- | --- | --- | --- | --- | --- | --- | --- | --- | --- | --- | --- | --- | --- | --- | --- |
| 137 | 22 | **Presence Capability** | 1103d? | 2001-03-19 A | 2005-06-08 | 99% | 6.16d? | 2001-03-19 | 2005-03-17 | 1044d? | 147d |  | S1 | 35032h | 34836.3h | PRESNC | Mark Cataldo, Motorola | Rel-6 | TSG | Michael | 11004 |  |  |
| 138 | 22.1 | Stage 1 | 610d | 2001-03-19 A | 2003-07-18 A | 100% |  | 2001-03-19 | 2003-07-18 | 610d |  | finish no earlier than 2003-07-18 | S1 | 4880h | 4880h |  |  | Rel-6 |  |  | 11005 | 22.141 |  |
| 139 | 22.2 | Stage 2 | 268d | 2001-09-12 A | 2002-09-20 A | 100% |  | 2001-09-12 | 2002-09-20 | 268d |  | finish no earlier than 2002-09-20 | S2 | 2144h | 2144h |  | Balazs BERTENYI, Nokia | Rel-6 | TSG |  |  |  | Balazs.Bertenyi@nokia.com |
| 140 | 22.3 | Stage 3 | 703d | 2002-04-01 A | 2004-12-08 A | 100% |  | 2002-04-01 | 2004-12-08 | 703d |  | finish no earlier than 2004-12-08 | N1 | 5624h | 5624h |  | Keith Drage, Lucent | Rel-6 |  |  |  |  | drage@lucent.com |
| 141 | 19.4 | Stage 3 (CN3 Part Pk interface) | 770d? | 2002-04-01 A | 2005-03-11 A | 100% |  | 2002-04-01 | 2005-03-11 | 770d? |  | finish no earlier than 2005-03-11 | N3 | 6160h | 6160h |  |  | Rel-6 |  |  |  |  |  |
| 142 | 19.5 | Media Codecs and Formats for IMS Messaging and Presence | 520d? | 2003-06-12 A | 2005-06-08 | 98% | 10.4d? | 2003-06-12 | 2005-03-17 | 461d? | 147d | finish no earlier than 2005-06-08 | S4 | 4160h | 4076.8h | PRESNC-COFIMP | Harri Honko (Nokia) | Rel-6 | TSG | Paolo |  | TS 26.141, TR 26.936 | harri.honko@nokia.com |
| 143 | 22.4 | Security issues | 79d | 2002-08-26 A | 2002-12-12 | 90% | 7.9d | 2002-08-26 | 2002-12-12 | 79d | 796d | finish no earlier than 2002-12-12 | S3 | 632h | 568.8h |  |  | Rel-6 |  |  |  |  |  |
| 144 | 19.7 | SIMPLE Presence | 326d? | 2004-01-01 A | 2005-03-31 A | 100% |  | 2004-01-01 | 2004-12-30 | 261d? |  | finish no earlier than 2004-12-30 | OMA | 2608h | 2608h |  |  | Rel-6 | n/a |  |  |  | OMA-LIAISON@mail.openmobilealliance.org |
| 145 | 25 | **Enhanced A/Gb feasibility study** | 51d? | 2002-08-30 A | 2002-11-08 A | 100% |  | 2002-08-30 | 2002-11-08 | 51d? |  |  | GP | 3264h | 3264h | AGbEnFS | J-L Carrizo, Vodafone | Rel-6 | TSG | Paolo |  |  | jose-luis.carrizo@vodafone.co.uk |
| 146 | 25.1 | **Feasibility study on A/Gb enhancements** | 51d? | 2002-08-30 A | 2002-11-08 A | 100% |  | 2002-08-30 | 2002-11-08 | 51d? |  |  | G2 | 2856h | 2856h | AGbEnFS-FS |  | Rel-6 | TSG |  |  |  |  |
| 147 | 25.1.1 | Requirements for the support of conversational services | 51d | 2002-08-30 A | 2002-11-08 A | 100% |  | 2002-08-30 | 2002-11-08 | 51d |  | finish no earlier than 2002-11-08 | GP | 408h | 408h |  |  | Rel-6 |  |  |  |  |  |
| 148 | 20.1.2 | Identification of the different building blocks for the provision of conversational services on the existing A/Gb protocol stack | 51d? | 2002-08-30 A | 2002-11-08 A | 100% |  | 2002-08-30 | 2002-11-08 | 51d? |  | finish no earlier than 2002-11-08 | GP | 408h | 408h |  |  | Rel-6 |  |  |  |  |  |
| 149 | 20.1.3 | Outline of impact and feasibility of these building blocks and their different solutions | 51d? | 2002-08-30 A | 2002-11-08 A | 100% |  | 2002-08-30 | 2002-11-08 | 51d? |  | finish no earlier than 2002-11-08 | GP | 408h | 408h |  |  | Rel-6 |  |  |  |  |  |
| 150 | 25.1.4 | Impact on 3GPP architecture and requirement to co-ordinatge with other TSGs (CN, SA) | 51d | 2002-08-30 A | 2002-11-08 A | 100% |  | 2002-08-30 | 2002-11-08 | 51d |  | finish no earlier than 2002-11-08 | GP | 408h | 408h |  |  | Rel-6 |  |  |  |  |  |
| 151 | 25.1.5 | Standardisation effort | 51d | 2002-08-30 A | 2002-11-08 A | 100% |  | 2002-08-30 | 2002-11-08 | 51d |  | finish no earlier than 2002-11-08 | GP | 408h | 408h |  |  | Rel-6 |  |  |  |  |  |
| 152 | 25.1.6 | Dependency to other features | 51d | 2002-08-30 A | 2002-11-08 A | 100% |  | 2002-08-30 | 2002-11-08 | 51d |  | finish no earlier than 2002-11-08 | GP | 408h | 408h |  |  | Rel-6 |  |  |  |  |  |
| 153 | 26 | **Flexible Layer One for GERAN** | 1170d | 2000-01-03 A | 2004-06-25 A | 100% |  | 2000-01-03 | 2004-06-25 | 1170d |  |  | GP | 71535h | 71535h | FLOGER | Benoist Sébire | Rel-6 | TSG | Paolo |  |  | benoist.sebire@nokia.com |
| 154 | 26.1 | **Realisation of a Flexible Layer One** | 1125d | 2000-01-03 A | 2004-04-23 A | 100% |  | 2000-01-03 | 2004-04-23 | 1125d |  |  | GP | 42808h | 42808h | FLOGER-Real | Benoist Sébire | Rel-6 |  |  |  |  | benoist.sebire@nokia.com |
| 155 | 26.1.1 | Technical Report | 471d | 2002-04-19 A | 2004-02-06 A | 100% |  | 2002-04-19 | 2004-02-06 | 471d |  | finish no earlier than 2004-02-06 | GP | 3768h | 3768h |  |  | Rel-6 |  |  |  |  |  |
| 156 | 26.1.2 | Architecture in 45.001 and 43.051 | 526d | 2002-04-19 A | 2004-04-23 A | 100% |  | 2002-04-19 | 2004-04-23 | 526d |  | finish no earlier than 2004-04-23 | G1 | 4208h | 4208h |  |  | Rel-6 |  |  |  |  |  |
| 157 | 26.1.3 | Multiplexing in 45.002 | 526d | 2002-04-19 A | 2004-04-23 A | 100% |  | 2002-04-19 | 2004-04-23 | 526d |  | finish no earlier than 2004-04-23 | G1 | 4208h | 4208h |  |  | Rel-6 |  |  |  |  |  |
| 158 | 26.1.4 | Channel Coding in 45.003 | 526d | 2002-04-19 A | 2004-04-23 A | 100% |  | 2002-04-19 | 2004-04-23 | 526d |  | finish no earlier than 2004-04-23 | G1 | 4208h | 4208h |  |  | Rel-6 |  |  |  |  |  |
| 159 | 26.1.5 | Performance Requirements in 45.005 | 1125d | 2000-01-03 A | 2004-04-23 A | 100% |  | 2000-01-03 | 2004-04-23 | 1125d |  | finish no earlier than 2004-04-23 | G1 | 9000h | 9000h |  |  | Rel-6 |  |  |  |  |  |
| 160 | 26.1.6 | Radio subsystem link control in 45.008 | 526d | 2002-04-19 A | 2004-04-23 A | 100% |  | 2002-04-19 | 2004-04-23 | 526d |  | finish no earlier than 2004-04-23 | G1 | 4208h | 4208h |  |  | Rel-6 |  |  |  |  |  |
| 161 | 26.1.7 | Requirements in 44.004 | 526d | 2002-04-19 A | 2004-04-23 A | 100% |  | 2002-04-19 | 2004-04-23 | 526d |  | finish no earlier than 2004-04-23 | G2 | 4208h | 4208h |  |  | Rel-6 |  |  |  |  |  |

Notes:
- 137: A Sultan merged "Presence Service Enhancements" (UID31028, PRES1) to this feature as no answer was provided on why Presence and Presence Encmts had same target completion date
- 140: Dependency to 2 IETF drafts, no known work at the moment
- 141: No Contributions so far - only requires a little work
- 142: Also for 31022 IMS Messaging
- 143: LSs handled in SA3. WID approved SA#17 Contribution at S3#25 & following e-mail discussion.
- 144: Updated according to SP-040232
- 145: Closed
- 153: Nokia, Ericsson, Siemens, Telia
- 154: Completed

| ID | WBS | Task | Type | Duration | Start | Finish | Complete | Remaining | Baseline start | Baseline finish | Baseline duration | Total slack | Constraint | Resources | Work | Actual work | Text1 | Text4 | Text5 | Text6 | Text3 | Text8 | Text7 | Text9 | Text12 |
| --- | --- | --- | --- | --- | --- | --- | --- | --- | --- | --- | --- | --- | --- | --- | --- | --- | --- | --- | --- | --- | --- | --- | --- | --- | --- |
| 162 | 26.2 | **Signalling and protocol support for a Flexible Layer One** |  | 571d | 2002-04-19 A | 2004-06-25 A | 100% |  | 2002-04-19 | 2004-06-25 | 571d |  |  | G2 | 13704h | 13704h | FLOGER-SigPro | Benoist Sébire | benoist.sebire@nokia.com | Rel-6 |  |  |  |  |  |
| 163 | 26.2.1 | Modifications to RLC/MAC in 44.060 and 44.160 |  | 571d | 2002-04-19 A | 2004-06-25 A | 100% |  | 2002-04-19 | 2004-06-25 | 571d |  | finish no earlier than 2004-06-25 | G2 | 4568h | 4568h |  |  |  | Rel-6 |  |  |  |  |  |
| 164 | 26.2.2 | Modifications to RRC in 44.118 and 44.018 |  | 571d | 2002-04-19 A | 2004-06-25 A | 100% |  | 2002-04-19 | 2004-06-25 | 571d |  | finish no earlier than 2004-06-25 | G2 | 4568h | 4568h |  |  |  | Rel-6 |  |  |  |  |  |
| 165 | 26.3 | **Security for a Flexible Layer One** |  | 356d | 2002-04-19 A | 2003-08-29 A | 100% |  | 2002-04-19 | 2003-08-29 | 356d |  |  | S3; G2 | 5663.04h | 5663.04h | FLOGER-SecFLO | Benoist Sébire | benoist.sebire@nokia.com | Rel-6 |  |  |  |  |  |
| 166 | 26.3.1 | Ciphering in 44.160,44.118, 44.060 and 44.018 |  | 356d | 2002-04-19 A | 2003-08-29 A | 100% |  | 2002-04-19 | 2003-08-29 | 356d |  | finish no earlier than 2003-08-29 | S3; G2 | 2848h | 2848h |  |  |  | Rel-6 |  |  |  |  |  |
| 167 | 26.4 | **Deleted at TSG#27 - GERAN MS Conformance test for the Flexible Layer One - DELETE** |  | 0d | 2004-02-06 A | 2004-02-06 A | 100% |  | 2004-02-06 | 2004-02-06 | 0d |  |  | G4; G5 |  |  | FLOGER-Msconf | Benoist Sébire | benoist.sebire@nokia.com | Rel-6 |  |  |  |  |  |
| 168 | 26.4.1 | deleted at TSG #27 - MS Test in 51.010 | milestone | 0d | 2004-02-06 A | 2004-02-06 A | 100% |  | 2004-02-06 | 2004-02-06 | 0d |  | finish no earlier than 2004-02-06 | G4; G5 |  |  |  |  |  | Rel-6 |  |  |  |  |  |
| 169 | 26.5 | **Deleted at TSG#27 - GERAN BTS Conformance test for the Flexible Layer One - DELETE** |  | 0d | 2004-02-06 A | 2004-02-06 A | 100% |  | 2004-02-06 | 2004-02-06 | 0d |  |  | G3 |  |  | FLOGER-BTSconf | Benoist Sébire | benoist.sebire@nokia.com | Rel-6 |  |  |  |  |  |
| 170 | 26.5.1 | Deleted at TGS #27 - BTS Test in 51.021 - DELETE | milestone | 0d | 2004-02-06 A | 2004-02-06 A | 100% |  | 2004-02-06 | 2004-02-06 | 0d |  | finish no earlier than 2004-02-06 | G3 |  |  |  |  |  | Rel-6 |  |  |  |  |  |
| 171 | 27 | Uplink TDOA feasibility study |  | 151d | 2001-11-30 A | 2002-06-28 A | 100% |  | 2001-11-30 | 2002-06-28 | 151d |  | finish no earlier than 2002-06-28 | GP | 1208h | 1208h | TDOAF | Bob Gross, TruePosition, Inc. | rlgross@trueposition.com | Rel-6 | 45.811 | Paolo |  |  |  |
| 172 | 28 | **Multimedia Broadcast and Multicast Service** |  | 1134d? | 2001-05-11 A | 2005-09-15 | 98% | 26.85d? | 2001-05-11 | 2005-09-15 | 1134d? | 77d |  | S1 | 132842h | 118778h | MBMS |  |  | Rel-6 |  | Michael | TSG |  |  |
| 173 | 28.1 | Stage 1 |  | 232d | 2001-05-11 A | 2002-04-01 A | 100% |  | 2001-05-11 | 2002-04-01 | 232d |  | finish no earlier than 2002-04-01 | S1 | 1856h | 1856h |  |  |  | Rel-6 | 22.146, 22.101 |  |  | 11003 |  |
| 174 | 28.2 | **Stage 2** |  | 648d | 2001-09-24 A | 2004-03-17 A | 100% |  | 2001-09-24 | 2004-03-17 | 648d |  |  | S2 | 10408h | 10408h |  |  |  | Rel-6 |  |  | TSG |  |  |
| 175 | 28.2.1 | TR on Architectural Study |  | 240d | 2001-09-24 A | 2002-08-23 A | 100% |  | 2001-09-24 | 2002-08-23 | 240d |  | finish no earlier than 2002-08-23 | S2 | 1920h | 1920h |  |  |  | Rel-6 | 23.846 |  |  |  |  |
| 176 | 28.2.2 | Stage 2 Specification Work |  | 413d | 2002-08-19 A | 2004-03-17 A | 100% |  | 2002-08-19 | 2004-03-17 | 413d |  | finish no earlier than 2004-03-17 | S2 | 3304h | 3304h |  |  |  | Rel-6 | 23.246 |  |  |  |  |
| 177 | 28.3 | **Introduction of MBMS in RAN** |  | 967d? | 2002-01-01 A | 2005-09-15 | 80% | 195.65d? | 2002-01-01 | 2005-09-15 | 967d? | 77d |  | R2 | 15992h | 11520h | MBMS-RAN | Juho Pirskanen , Nokia | juho.pirskanen@nokia.com | Rel-6 | TS 25.346, TS 25.304, 25.321, 25.322, 25.323, 25.331 | MCC_RAN | TSG | 2481 |  |
| 178 | 23.3.1 | Introduction of MBMS in RAN (physical & upper layers, access network interfaces) |  | 771d? | 2002-01-01 A | 2004-12-14 A | 100% |  | 2002-01-01 | 2004-12-14 | 771d? |  | finish no earlier than 2004-12-14 | R2 | 6168h | 6168h | MBMS-RAN | Juho Pirskanen , Nokia | juho.pirskanen@nokia.com | Rel-6 | TS 25.346, TS 25.304, 25.321, 25.322, 25.323 | MCC_RAN | TSG |  |  |
| 179 | 23.3.2 | UE Performance Requirements for MBMS |  | 261d? | 2004-09-15 A | 2005-09-15 | 20% | 208.8d? | 2004-09-15 | 2005-09-15 | 261d? | 77d | finish no earlier than 2005-09-15 | R4 | 2088h | 417.6h | MBMS-RAN-RF | Torgny Palenius, Ericsson | Torgny.Palenius@ericsson.com | Rel-6 | TS25.101, TS25.133 | MCC_RAN | TSG |  |  |
| 180 | 28.4 | Support of the MBMS in CN protocols |  | 647d | 2002-06-18 A | 2004-12-08 | 97% | 19.41d | 2002-06-18 | 2004-12-08 | 647d | 277d | finish no earlier than 2004-12-08 | N1 | 5176h | 5020.72h |  |  |  | Rel-6 |  |  | TSG |  |  |
| 181 | 23.5 | Gmb interface for MBMS (CN3 part) |  | 334d | 2003-08-29 A | 2004-12-08 A | 100% |  | 2003-08-29 | 2004-12-08 | 334d |  | finish no earlier than 2004-12-08 | N3 | 2672h | 2672h |  |  |  | Rel-6 | 29.061 |  |  |  |  |
| 182 | 28.5 | Security Aspects of MBMS |  | 710d | 2002-07-01 A | 2005-03-18 | 95% | 35.5d | 2002-07-01 | 2005-03-18 | 710d | 205d | finish no earlier than 2005-03-18 | S3 | 5680h | 5396h | MBMS | Escott, Adrian, 3 | adrian.escott@three.co.uk | Rel-6 |  |  | TSG |  |  |
| 183 | 28.6 | **Support of MBMS in GERAN** |  | 892d? | 2001-08-30 A | 2005-01-28 A | 100% |  | 2001-08-30 | 2005-01-28 | 892d? |  |  | GP | 71040h | 71040h | MBMS-GERAN |  |  | Rel-6 |  |  | TSG |  |  |
| 184 | 28.6.1 | Impact on the logical and physical channels |  | 631d | 2002-08-30 A | 2005-01-28 A | 100% |  | 2002-08-30 | 2005-01-28 | 631d |  | finish no earlier than 2005-01-28 | GP | 5048h | 5048h |  |  |  | Rel-6 |  |  |  |  |  |
| 185 | 28.6.4 | Re-synchronisation at cell change |  | 631d | 2002-08-30 A | 2005-01-28 A | 100% |  | 2002-08-30 | 2005-01-28 | 631d |  | finish no earlier than 2005-01-28 | G2 | 5048h | 5048h |  |  |  | Rel-6 |  |  |  |  |  |
| 186 | 23.7.3 | Simultaneous support of MBMS services |  | 631d? | 2002-08-30 A | 2005-01-28 A | 100% |  | 2002-08-30 | 2005-01-28 | 631d? |  | finish no earlier than 2005-01-28 | GP | 5048h | 5048h |  |  |  | Rel-6 |  |  |  |  |  |
| 187 | 23.7.4 | Simultaneous support of MBMS and non-MBMS services |  | 892d? | 2001-08-30 A | 2005-01-28 A | 100% |  | 2001-08-30 | 2005-01-28 | 892d? |  | finish no earlier than 2005-01-28 | GP | 7136h | 7136h |  |  |  | Rel-6 |  |  |  |  |  |
| 188 | 23.7.5 | Resynchronisation at cell change |  | 892d? | 2001-08-30 A | 2005-01-28 A | 100% |  | 2001-08-30 | 2005-01-28 | 892d? |  | finish no earlier than 2005-01-28 | GP | 7136h | 7136h |  |  |  | Rel-6 |  |  |  |  |  |
| 189 | 28.6.5 | Decision making process between point-to-point or pont-to-multipoint configurations |  | 631d | 2002-08-30 A | 2005-01-28 A | 100% |  | 2002-08-30 | 2005-01-28 | 631d |  | finish no earlier than 2005-01-28 | GP | 5048h | 5048h |  |  |  | Rel-6 |  |  |  |  |  |
| 190 | 28.6.6 | MBMS channel allocations procedures to multiple MSs |  | 631d | 2002-08-30 A | 2005-01-28 A | 100% |  | 2002-08-30 | 2005-01-28 | 631d |  | finish no earlier than 2005-01-28 | GP | 5048h | 5048h |  |  |  | Rel-6 |  |  |  |  |  |
| 191 | 28.6.7 | Changes to the Gb interface |  | 631d | 2002-08-30 A | 2005-01-28 A | 100% |  | 2002-08-30 | 2005-01-28 | 631d |  | finish no earlier than 2005-01-28 | GP | 5048h | 5048h |  |  |  | Rel-6 |  |  |  |  |  |
| 192 | 28.6.8 | GERAN specific changes to the Iu-ps interface |  | 631d | 2002-08-30 A | 2005-01-28 A | 100% |  | 2002-08-30 | 2005-01-28 | 631d |  | finish no earlier than 2005-01-28 | GP | 5048h | 5048h |  |  |  | Rel-6 |  |  |  |  |  |
| 193 | 28.6.9 | Interaction between MBMS and Iu-flex |  | 631d | 2002-08-30 A | 2005-01-28 A | 100% |  | 2002-08-30 | 2005-01-28 | 631d |  | finish no earlier than 2005-01-28 | GP | 5048h | 5048h |  |  |  | Rel-6 |  |  |  |  |  |
| 194 | 28.6.10 | Security aspects |  | 631d | 2002-08-30 A | 2005-01-28 A | 100% |  | 2002-08-30 | 2005-01-28 | 631d |  | finish no earlier than 2005-01-28 | GP | 5048h | 5048h |  |  |  | Rel-6 |  |  |  |  |  |
| 195 | 23.7.12 | MS conformance tests- G3 |  | 786d? | 2002-01-25 A | 2005-01-28 A | 100% |  | 2002-08-30 | 2005-01-28 | 631d? |  | finish no earlier than 2005-01-28 | G3 | 6288h | 6288h |  |  |  | Rel-6 |  |  |  |  |  |
| 196 | 23.7.13 | Deleted - MS conformance tests - G5 | milestone | 0d? | 2003-06-27 A | 2003-06-27 A | 100% |  | 2003-06-27 | 2003-06-27 | 0d? |  | start no earlier than 2003-06-27 | G5 |  |  |  |  |  | Rel-6 |  |  |  |  | GP-19 |

Notes:
- 162: Completed
- 165: Started
- 167: DELETE
- 168: DELETE
- 169: DELETE
- 170: DELETE
- 172: Title renamed at SA#13
- 173: This may or may not be a separate stage 1. In the meantime, CRs are proposed for 22.101
- 178: Was "Introduction of MBMS in RAN" before RP#25. Created w/o WIDS after RAN approved the WT for RF aspects.Take WIDS from the parent BB
- 179: Approved at RP#25 as RP-040370
- 182: WID approved SA#17. 2004-12: Expected completion March 2005
- 183: Completed
- 195: Under evaluation

| ID | WBS | Task | Type | Duration | Start | Finish | Complete | Remaining | Baseline start | Baseline finish | Baseline duration | Total slack | Constraint | Resources | Work | Actual work | Text3 | Text6 | Text8 | Text9 | Text1 | Text4 | Text5 | Text7 | Text10 | Text12 |
| --- | --- | --- | --- | --- | --- | --- | --- | --- | --- | --- | --- | --- | --- | --- | --- | --- | --- | --- | --- | --- | --- | --- | --- | --- | --- | --- |
| 197 | 28.1 | **MBMS User Services** |  | 542d? | 2003-05-13 A | 2005-06-08 | 99% | 7.49d? | 2003-05-13 | 2005-03-17 | 483d? | 147d |  | S1 | 10360h | 10216.9h | 22.246 | Rel-6 | Michael | 11003 |  |  |  |  |  |  |
| 198 | 28.1 | MBMS User Services Stage 1 |  | 233d | 2003-05-13 A | 2004-04-01 A | 100% |  | 2003-05-13 | 2004-04-01 | 233d |  | start no earlier than 2003-05-13 | S1 | 1864h | 1864h | 22.246 | Rel-6 | Michael | 11003 |  |  |  |  |  |  |
| 199 | 23.8.2 | Definition of MBMS user services, media codecs, formats and transport/application protocols using MBMS |  | 520d? | 2003-06-12 A | 2005-06-08 | 98% | 10.4d? | 2003-06-12 | 2005-03-17 | 461d? | 147d | finish no earlier than 2005-06-08 | S4 | 4160h | 4076.8h | 26.346, 26.936, 26.946 | Rel-6 | Paolo |  | MBMS-TSMBMS | Igor Curcio (Nokia) | igor.curcio@nokia.com | TSG |  |  |
| 200 | 23.9 | MBMS charging |  | 108d? | 2005-01-11 A | 2005-06-09 | 75% | 27d? | 2005-01-11 | 2005-06-09 | 108d? | 146d | start no earlier than 2005-01-11 | S5 | 864h | 648h | 32.273 | Rel-6 |  |  | MBMS-CH |  |  | TSG |  |  |
| 201 | 29 | **Speech Recognition and Speech Enabled Services** |  | 1105d? | 2001-10-08 A | 2005-12-30 | 85% | 170d? | 2001-10-08 | 2005-06-30 | 974d? | 0d |  | S1 | 20176h | 17072h |  | Rel-6 | Michael |  | SRSES |  |  | TSG |  |  |
| 202 | 29.1 | Speech Enabled Services Based on Distributed Speech Recognition (DSR) |  | 115d | 2001-10-08 A | 2002-03-15 A | 100% |  | 2001-10-08 | 2002-03-15 | 115d |  | finish no earlier than 2002-03-15 | S1 | 920h | 920h | 22.941, 23.207, 22.243 | Rel-6 |  |  | DSR | D Williams, QUALCOMM, Inc. | Dwilliams@qualcomm.com | TSG |  |  |
| 203 | 29.2 | TR on Architectural impacts |  | 212d | 2003-05-12 A | 2004-03-02 A | 100% |  | 2003-05-12 | 2004-03-02 | 212d |  | finish no earlier than 2004-03-02 | S2 | 1696h | 1696h | 23.877 | Rel-6 |  |  |  |  |  |  |  |  |
| 204 | 24.3 | Codec Work to Support Speech Recognition Framework for Automated Voice Services |  | 568d? | 2002-10-15 A | 2004-12-16 A | 100% |  | 2002-10-15 | 2004-12-16 | 568d? |  | finish no earlier than 2004-12-16 | S4 | 4544h | 4544h | 26.235, 26.236, 26.243, 26.177, 26.943 | Rel-6 | Paolo |  | SRSES-Codec | David Pearce, Motorola | bdp003@motorola.com | WG |  |  |
| 205 | 24.4 | Multimodal support |  | 522d? | 2004-01-01 A | 2005-12-30 | 58% | 218d? | 2004-01-01 | 2005-06-30 | 391d? | 0d | finish no earlier than 2005-06-30 | OMA | 4176h | 2432h |  | Rel-6 |  |  |  |  | OMA-LIAISON@mail.openmobilealliance.org |  | SP-24 |  |
| 206 | 24.5 | Deleted - SES codec negotiation at SDP | milestone | 0d? | 2003-06-04 A | 2003-06-04 A | 100% |  | 2003-06-04 | 2003-06-04 | 0d? |  | start no earlier than 2003-06-04 | N1 |  |  |  | Rel-6 |  |  |  |  |  |  |  | NP-23 |
| 207 | 30 | **Generic User Profile Rel-6** |  | 889d | 2001-10-08 A | 2005-03-03 | 97% | 29.11d | 2001-10-08 | 2005-03-03 | 889d | 216d |  | S1 | 24295.8h | 23500.1h |  | Rel-6 | Michael |  | GUP |  |  | TSG |  |  |
| 208 | 30.1 | Stage 1 - Requirements |  | 430d | 2001-10-08 A | 2003-05-30 A | 100% |  | 2001-10-08 | 2003-05-30 | 430d |  | finish no earlier than 2002-12-09 | S1 | 3440h | 3440h | 22.240, 22.228 | Rel-6 |  |  |  | Kurt Bischinger (T-Mobile) | kurt.bischinger@t-mobile.at |  |  |  |
| 209 | 30.3 | Stage 2 - Architecture |  | 355d | 2002-01-28 A | 2003-06-06 A | 100% |  | 2002-01-28 | 2003-06-06 | 355d |  | finish no earlier than 2003-06-06 | S2 | 2840h | 2840h | 23.240 | Rel-6 |  |  |  | Harri KOSKINEN, Nokia | harri.o.koskinen@nokia.com |  |  |  |
| 210 | 30.2 | Stage 2 - Data Description Method |  | 586d | 2002-12-05 A | 2005-03-03 A | 100% |  | 2002-12-05 | 2005-03-03 | 586d |  | finish no earlier than 2005-03-03 | N4 | 4688h | 4688h | 23.241 | Rel-6 | Friedhelm |  |  | Kurt Bischinger (T-Mobile AUSTRIA) | kurt.bischinger@t-mobile.at | TSG |  |  |
| 211 | 30.5 | Stage 3 - Network |  | 468.98d | 2003-05-19 A | 2005-03-03 | 85% | 70.35d | 2003-05-19 | 2005-03-03 | 468.98d | 216d | finish no earlier than 2005-03-03 | N4 | 3751.84h | 3189.06h | 29.240 | Rel-6 |  |  |  |  |  |  |  |  |
| 212 | 30.6 | Security Aspects |  | 308d | 2002-07-16 A | 2003-09-18 A | 100% |  | 2002-07-16 | 2003-09-18 | 308d |  | finish no earlier than 2003-09-18 | S3 | 2464h | 2464h | 33.102, 33.203, 33.210 | Rel-6 |  |  |  | Owen, Bradley | bvowen@lucent.com | WG |  |  |
| 213 | 31 | **Digital Rights Management** |  | 690d? | 2001-10-08 A | 2004-05-28 A | 100% |  | 2001-10-08 | 2004-05-28 | 690d? |  |  | S1 | 10152h | 10152h |  | Rel-6 | Michael |  | DRM |  |  | TSG |  |  |
| 214 | 31.1 | Requirements |  | 179d | 2001-10-08 A | 2002-06-13 A | 100% |  | 2001-10-08 | 2002-06-13 | 179d |  | finish no earlier than 2002-06-13 | S1 | 1432h | 1432h |  | Rel-6 |  |  |  | Nicholas Wood, Openwave Systems | nicholas.wood@openwave.com |  |  |  |
| 215 | 26.2 | Deleted - Monitoring of Stages 2 and 3 progress (actual work to be done by OMA) | milestone | 0d? | 2003-03-21 A | 2003-03-21 A | 100% |  | 2003-03-21 | 2003-03-21 | 0d? |  | start no earlier than 2002-08-19 | S1 |  |  |  | Rel-6 |  |  |  |  |  |  |  |  |
| 216 | 26.3 | Stage 2 |  | 107d? | 2004-01-01 A | 2004-05-28 A | 100% |  | 2004-01-01 | 2004-05-28 | 107d? |  | finish no earlier than 2004-05-28 | OMA | 856h | 856h |  | Rel-6 |  |  |  |  | OMA-LIAISON@mail.openmobilealliance.org |  | SP-24 |  |
| 217 | 26.4 | Stage 3 |  | 107d? | 2004-01-01 A | 2004-05-28 A | 100% |  | 2004-01-01 | 2004-05-28 | 107d? |  | finish no earlier than 2004-05-28 | OMA | 856h | 856h |  | Rel-6 |  |  |  |  | OMA-LIAISON@mail.openmobilealliance.org |  | SP-24 |  |
| 218 | 31.3 | Security |  | 186d | 2002-06-17 A | 2003-03-03 A | 100% |  | 2002-06-17 | 2003-03-03 | 186d |  | finish no earlier than 2003-03-03 | OMA | 1488h | 1488h |  | Rel-6 |  |  |  |  |  |  |  |  |
| 219 | 32 | **WLAN-UMTS Interworking Rel-6** |  | 1419d? | 2000-01-03 A | 2005-06-09 | 97% | 47.75d? | 2000-01-03 | 2005-06-09 | 1419d? | 146d |  | S1 | 47264h | 45704.4h |  | Rel-6 | Michael |  | WLAN | Fredric Paint, Telenor | frederic.paint@telenor.com | TSG |  |  |
| 220 | 32.1 | Technical Report |  | 900d? | 2000-01-03 A | 2003-06-13 A | 100% |  | 2000-01-03 | 2003-06-13 | 900d? |  | finish no earlier than 2003-06-13 | S1 | 7200h | 7200h | 22.934, 22.101, 22.105 | Rel-6 |  |  | WLAN-TR | Fredric Paint, Telenor | frederic.paint@telenor.com |  |  |  |

Notes:
- 199: TR tbc by Sept. 05
- 200: SA#26: Approved WID SP-040778. Target TS Approval 06/2005.
- 204: Completed
- 206: Abandoned NP-23
- 210: TR approved in CN#26
- 211: 17 May no activity in CN4............
- 212: WID approved SA#17. SA WG3 progress slow, depends on progress in other groups.
- 213: Foreseen start and completion dates introduced by MCC (no indication at all on the WID)
- 215: Replaced by UID 60005 and 60006
- 218: SA3 acknowledge role in WI at SA3#20. Active contribution S3#24, S3#25. S3 WID approved SA#17

| ID | WBS | Task | Duration | Start | Finish | Complete | Remaining | Baseline start | Baseline finish | Baseline duration | Total slack | Constraint | Resources | Work | Actual work | Text1 | Text3 | Text4 | Text5 | Text6 | Text10 | Text7 | Text8 | Text9 | Text11 |
| --- | --- | --- | --- | --- | --- | --- | --- | --- | --- | --- | --- | --- | --- | --- | --- | --- | --- | --- | --- | --- | --- | --- | --- | --- | --- |
| 221 | 27.2 | **Stage 1** | 375d? | 2003-01-06 A | 2004-06-11 A | 100% |  | 2003-01-06 | 2004-06-11 | 375d? |  |  | S1 | 3920h | 3920h | WLAN-TS | 22.234 | Fredric Paint, Telenor | frederic.paint@telenor.com | Rel-6 | SP-24 |  |  |  |  |
| 222 | 27.2.1 | Global stage 1 | 375d? | 2003-01-06 A | 2004-06-11 A | 100% |  | 2003-01-06 | 2004-06-11 | 375d? |  | finish no earlier than 2004-06-11 | S1 | 3000h | 3000h | WLAN-TS | 22.234 | Fredric Paint, Telenor | frederic.paint@telenor.com | Rel-6 | SP-24 |  |  |  |  |
| 223 | 32.2 | Architecture Definition for scenarii 2 and 3 | 571d | 2002-03-25 A | 2004-05-31 A | 100% |  | 2002-03-25 | 2004-05-31 | 571d |  | finish no earlier than 2004-05-31 | S2 | 4568h | 4568h |  | 23.234 |  |  | Rel-6 |  | TSG |  |  |  |
| 224 | 32.3 | Security | 125d | 2002-09-30 A | 2003-03-21 A | 100% |  | 2002-09-30 | 2003-03-21 | 125d |  | finish no earlier than 2003-03-21 | S3 | 1000h | 1000h |  | 21.133, 33.106, 33.107, 33.108, 33.200, 33.203, 33.210 | Lopez-Soria, Luis, Ericsson | luis.lopez-soria@ece.ericsson.se | Rel-6 |  | TSG |  |  |  |
| 225 | 27.5 | Stage 3 - CN4 aspects | 334d? | 2003-05-23 A | 2004-09-01 | 85% | 50.1d? | 2003-05-23 | 2004-09-01 | 334d? | 347d | finish no earlier than 2004-09-01 | N4 | 2672h | 2271.2h | WLAN-IW | 29.234, 29.061 | Rodriguez ,Raquel, Nokia | raquel.rodriguez@nokia.com | Rel-6 |  | TSG |  |  |  |
| 226 | 27.6 | Stage 3 - CN3 aspects (Wi Interface for Scenario 3) | 355d? | 2003-05-23 A | 2004-09-30 A | 100% |  | 2003-05-23 | 2004-09-30 | 355d? |  | start no earlier than 2003-05-23 | N3 | 2840h | 2840h | WLAN | 29.161 |  |  | Rel-6 | SP-24 | TSG |  |  |  |
| 227 | 27.7 | Stage 3 for scenario 2 | 339d? | 2003-05-23 A | 2004-09-08 A | 100% |  | 2003-05-23 | 2004-09-08 | 339d? |  | finish no earlier than 2004-09-08 | N1 | 2712h | 2712h |  |  |  |  | Rel-6 |  | WG |  |  |  |
| 228 | 27.8 | Stage 3 for scenario 3 | 404d? | 2003-05-23 A | 2004-12-08 A | 100% |  | 2003-05-23 | 2004-12-08 | 404d? |  | finish no earlier than 2004-12-08 | N1 | 3232h | 3232h |  |  |  |  | Rel-6 | SP-24 | WG |  |  |  |
| 229 | 27.9 | WLAN charging | 580d? | 2003-03-21 A | 2005-06-09 | 90% | 58d? | 2003-03-21 | 2005-06-09 | 580d? | 146d | finish no earlier than 2005-06-09 | S5 | 4640h | 4176h | WLAN-CH | 32.252 |  |  | Rel-6 |  | TSG |  |  |  |
| 230 | 27.10 | USIM enhancements for WLAN Interworking | 391d? | 2003-09-05 A | 2005-03-04 | 90% | 39.1d? | 2003-09-05 | 2005-03-04 | 391d? | 215d | finish no earlier than 2005-03-04 | T3 | 3128h | 2815.2h |  |  | Jorge Abellan | Jabellan@axalto.com | Rel-6 |  | TSG |  |  |  |
| 231 | 33 | **Priority Service** | 666d? | 2002-05-30 A | 2004-12-16 | 80% | 130.02d? | 2002-05-30 | 2004-12-16 | 666d? | 271d |  | S1 | 12616h | 10153h | NTShar |  |  |  | Rel-6 |  | TSG | Michael |  |  |
| 232 | 33.1 | Feasibility Study | 1d | 2002-06-14 A | 2002-06-14 A | 100% |  | 2002-06-14 | 2002-06-14 | 1d |  | finish no earlier than 2002-06-14 | S1 | 8h | 8h | PRIOR-FS | 22.950 | Biplab K. Pramanik, Telcordia Technologies | bpramani@telcordia.com | Rel-6 |  |  | Michael |  |  |
| 233 | 33.2 | Stage 1 - Requirements | 340d | 2002-05-30 A | 2003-09-17 A | 100% |  | 2002-05-30 | 2003-09-17 | 340d |  | finish no earlier than 2003-09-17 | S1 | 2720h | 2720h | PRIOR-SR |  | James J. Garrahan, Telcordia Technologies | bpramani@telcordia.com | Rel-6 |  |  | Michael |  |  |
| 234 | 28.3 | Multimedia Priority Service | 450d? | 2003-03-28 A | 2004-12-16 | 60% | 180d? | 2003-03-28 | 2004-12-16 | 450d? | 271d | finish no earlier than 2004-12-16 | S1 | 3600h | 2160h |  | 22.953 |  |  | Rel-6 |  |  |  |  |  |
| 235 | 28.4 | Priority service implementation guide | 131d? | 2003-03-28 A | 2003-09-26 A | 100% |  | 2003-03-28 | 2003-09-26 | 131d? |  | finish no earlier than 2003-09-26 | S1 | 1048h | 1048h |  | 22.952 | Biplab K. Pramanik, Telcordia Technologies | bpramani@telcordia.com | Rel-6 |  |  |  |  |  |
| 236 | 34 | **Network Sharing** | 498d? | 2003-01-20 A | 2004-12-15 A | 100% |  | 2003-01-20 | 2004-12-15 | 498d? |  |  | S1 | 16608h | 16608h | NTShar |  |  |  | Rel-6 |  | TSG | Michael |  |  |
| 237 | 34.1 | Technical Report | 240d? | 2003-01-20 A | 2003-12-19 A | 100% |  | 2003-01-20 | 2003-12-19 | 240d? |  |  | S1 | 1920h | 1920h | NTShar-TR | 22.951 |  |  | Rel-6 |  |  | Michael |  |  |
| 238 | 29.2 | Stage 1 - CRs to implement Network Sharing | 240d? | 2003-01-20 A | 2003-12-19 A | 100% |  | 2003-01-20 | 2003-12-19 | 240d? |  | finish no earlier than 2003-12-19 | S1 | 1920h | 1920h | NTShar-CR | 22.011, 22.101, 22.115, 22.129 |  |  | Rel-6 |  |  |  |  |  |
| 239 | 29.3 | Stage 2 | 372d? | 2003-02-27 A | 2004-07-30 A | 100% |  | 2003-02-27 | 2004-07-30 | 372d? |  | finish no earlier than 2004-07-30 | S2 | 2976h | 2976h |  | 23.251 |  |  | Rel-6 |  |  |  |  |  |
| 240 | 29.4 | Network sharing - stage 3 | 404d? | 2003-05-23 A | 2004-12-08 A | 100% |  | 2003-05-23 | 2004-12-08 | 404d? |  | finish no earlier than 2004-12-08 | N1 | 3232h | 3232h |  |  |  |  | Rel-6 |  | TSG |  |  |  |
| 241 | 29.5 | Enhancement of the support of network sharing in the UTRAN | 324d | 2003-09-19 A | 2004-12-15 A | 100% |  | 2003-09-19 | 2004-12-15 | 324d |  | finish no earlier than 2004-12-15 | R2 | 2592h | 2592h | NTShar-UTRANEnh | TS25.401, TS25.413, TS25.331, TS25.304 | Anders Dahlén, TeliaSonera | Anders.Dahlen@TeliaSonera.com | Rel-6 |  | TSG | MCC_RAN | BB | Active |
| 242 | 35 | **QoS Improvements** | 628d? | 2002-07-15 A | 2004-12-08 A | 100% |  | 2002-07-15 | 2004-12-08 | 628d? |  |  | S2 | 13128h | 13128h | QoS1 |  |  |  | Rel-6 |  | TSG | Sang-Ui |  |  |
| 243 | 35.1 | FS on Dynamic Policy control enhancements for end-to-end QoS | 465d | 2002-07-15 A | 2004-04-23 A | 100% |  | 2002-07-15 | 2004-04-23 | 465d |  | finish no earlier than 2004-04-23 | S2 | 3720h | 3720h | QoS1 | 23.917 |  | Claire Mousset, Nortel | Rel-6 |  | TSG |  |  |  |
| 244 | 30.2 | Definition of the Gq interface | 214d? | 2003-07-01 A | 2004-04-23 A | 100% |  | 2003-07-01 | 2004-04-23 | 214d? |  | finish no earlier than 2004-04-23 | S2 | 1712h | 1712h |  | 23.221 | Janne Rinne (Nokia) |  | Rel-6 |  |  |  |  |  |
| 245 | 30.3 | Gq interface specification for Dynamic Policy control enhancements – Stage 3 | 334d | 2003-08-29 A | 2004-12-08 A | 100% |  | 2003-08-29 | 2004-12-08 | 334d |  | finish no earlier than 2004-12-08 | N3 | 2672h | 2672h |  | 24,228, 29.207, 29.208 | Anna Sillanpää, Nokia | Anna.Sillanpaai@nokia.com | Rel-6 |  | TSG |  |  |  |

Notes:
- 224: Active contribution S3#24, S3#25. WID approved SA#17
- 225: WID approved at CN#19...............
- 229: Target 06/2005 completed
- 245: [DAB - 25.05.04] - Delayed to Sept - possibly Dec 2004

| ID | WBS | Task | Type | Duration | Start | Finish | Complete | Remaining | Baseline start | Baseline finish | Baseline duration | Total slack | Constraint | Resources | Work | Actual work | Text1 | Text4 | Text5 | Text6 | Text7 | Text8 | Text10 | Text12 |
| --- | --- | --- | --- | --- | --- | --- | --- | --- | --- | --- | --- | --- | --- | --- | --- | --- | --- | --- | --- | --- | --- | --- | --- | --- |
| 246 | 36 | **Subscriber certificates** |  | 728d? | 2002-02-25 A | 2004-12-08 A | 100% |  | 2002-02-25 | 2004-12-08 | 728d? |  |  | S3 | 12888h | 12888h | SEC1-SC | Valtteri Niemi, Nokia | valtteri.niemi@nokia.com | Rel-6 | TSG | Maurice |  |  |
| 247 | 36.1 | Stage 1 |  | 144d | 2002-02-25 A | 2002-09-12 A | 100% |  | 2002-02-25 | 2002-09-12 | 144d |  | finish no earlier than 2002-09-12 | S3 | 1152h | 1152h |  |  |  | Rel-6 |  |  |  |  |
| 248 | 36.2 | Architecture review |  | 24d | 2002-10-14 A | 2002-11-14 A | 100% |  | 2002-10-14 | 2002-11-14 | 24d |  | finish no earlier than 2002-11-14 | S2 | 192h | 192h |  |  |  | Rel-6 |  |  |  |  |
| 249 | 31.3 | Stage 3 |  | 313d? | 2003-09-19 A | 2004-11-30 A | 100% |  | 2003-09-19 | 2004-11-30 | 313d? |  | finish no earlier than 2004-11-30 | N4 | 2504h | 2504h | SEC1-SC | Lauri Laitinen, Nokia |  | Rel-6 |  | Kimmo |  |  |
| 250 | 31.4 | Stage 3 Ua & Ub interfaces |  | 288d? | 2003-11-03 A | 2004-12-08 A | 100% |  | 2003-11-03 | 2004-12-08 | 288d? |  | finish no earlier than 2004-12-08 | N1 | 2304h | 2304h |  |  |  | Rel-6 |  |  |  |  |
| 251 | 31.5 | OMA dependencies on Subscriber certificates |  | 114d? | 2004-01-01 A | 2004-06-08 A | 100% |  | 2004-01-01 | 2004-06-08 | 114d? |  | finish no earlier than 2004-06-08 | OMA | 912h | 912h |  |  | OMA-LIAISON@mail.openmobilealliance.org | Rel-6 | n/a |  | SP-24 |  |
| 252 | 32 | **Rel-6 OSA enhancements** |  | 616d? | 2002-10-31 A | 2005-03-10 | 99% | 0d? | 2002-10-31 | 2005-03-10 | 616d? | 0d |  | N5 | 22576h | 19024h | OSA3 | Chelo ABARCA (Alcatel) | Chelo.Abarca@alcatel.fr | Rel-6 | TSG | Adrian |  |  |
| 253 | 32.1 | Scope of the Open Service Access Release 6 |  | 66d? | 2003-03-28 A | 2003-06-27 A | 100% |  | 2003-03-28 | 2003-06-27 | 66d? |  | finish no earlier than 2003-06-27 | S1 | 528h | 528h |  |  |  | Rel-6 | TSG |  |  |  |
| 254 | 32.2 | OSA Stage 2 |  | 150d? | 2004-08-13 A | 2005-03-10 A | 100% |  | 2004-08-13 | 2005-03-10 | 150d? |  | finish no earlier than 2005-03-10 | N5 | 1200h | 1200h |  |  |  | Rel-6 | TSG |  |  |  |
| 255 | 32.3 | Multi Media Messaging function |  | 487d? | 2002-10-31 A | 2004-09-10 A | 100% |  | 2002-10-31 | 2004-09-10 | 487d? |  | finish no earlier than 2004-09-10 | N5 | 3896h | 3896h |  |  |  | Rel-6 | TSG |  |  |  |
| 256 | 32.4 | Policy management extensions |  | 292d? | 2002-10-31 A | 2003-12-12 A | 100% |  | 2002-10-31 | 2003-12-12 | 292d? |  | finish no earlier than 2003-12-12 | N5 | 2336h | 2336h |  |  |  | Rel-6 | TSG |  |  |  |
| 257 | 32.5 | TS on Presence and Availability Management (from the PRESNC WI) |  | 367d? | 2002-10-31 A | 2004-03-26 A | 100% |  | 2002-10-31 | 2004-03-26 | 367d? |  | finish no earlier than 2004-03-26 | N5 | 2936h | 2936h |  |  |  | Rel-6 | TSG |  |  |  |
| 258 | 32.6 | OSA interfaces at different levels of abstractions (Parlay X, Web services) |  | 305d? | 2003-07-14 A | 2004-09-10 A | 100% |  | 2003-07-14 | 2004-09-10 | 305d? |  | finish no earlier than 2004-09-10 | N5 | 2440h | 2440h |  |  |  | Rel-6 | TSG |  |  |  |
| 259 | 32.7 | Introduction of migration support mechanism |  | 290d? | 2002-10-31 A | 2003-12-10 A | 100% |  | 2002-10-31 | 2003-12-10 | 290d? |  | finish no earlier than 2003-12-12 | N5 | 2320h | 2320h |  |  |  | Rel-6 | TSG |  |  |  |
| 260 | 32.8 | Framework Function for Federation |  | 225d? | 2003-02-03 A | 2003-12-12 A | 100% |  | 2003-02-03 | 2003-12-12 | 225d? |  | finish no earlier than 2003-12-12 | N5 | 1800h | 1800h |  |  |  | Rel-6 | TSG |  |  |  |
| 261 | 32.9 | OMA potential overlaps with 3GPP OSA Stage 3 (Web services) |  | 196d? | 2003-12-18 A | 2004-09-16 A | 100% |  | 2003-12-18 | 2004-09-16 | 196d? |  | start no earlier than 2003-12-18 | OMA | 1568h | 1568h |  |  |  | Rel-6 | n/a |  | SP-24 |  |
| 262 | 32.10 | Deleted - TR on Presence and Availability Management (from the PRESNC WI) | milestone | 0d? | 2004-09-17 A | 2004-09-17 A | 100% |  | 2004-09-17 | 2004-09-17 | 0d? |  | start no earlier than 2004-09-17 | N5 |  |  |  |  |  | Rel-6 |  |  |  | NP-24 |
| 263 | 39 | **Addition of frequency bands to GSM (TAPS)** |  | 676d | 2002-06-28 A | 2005-01-28 A | 100% |  | 2002-06-28 | 2005-01-28 | 676d |  |  | GP | 16640h | 16640h | TAPS | Torben Themsen |  | Rel-6 | TSG | Paolo |  |  |
| 264 | 39.1 | **Addition of frequency bands to GSM – Changes to core specs** |  | 26d | 2002-11-15 A | 2002-12-20 A | 100% |  | 2002-11-15 | 2002-12-20 | 26d |  |  | G1 | 416h | 416h | TAPS-Specs | Torben Themsen |  | Rel-6 | TSG |  |  |  |
| 265 | 39.1.1 | Changes to core specs |  | 26d | 2002-11-15 A | 2002-12-20 A | 100% |  | 2002-11-15 | 2002-12-20 | 26d |  | finish no earlier than 2002-12-20 | G1 | 208h | 208h |  |  |  | Rel-6 |  |  |  |  |
| 266 | 39.2 | **Deleted at TSG #27 - Addition of frequency bands to GSM – Changes for conformance tests** |  | 676d | 2002-06-28 A | 2005-01-28 A | 100% |  | 2002-06-28 | 2005-01-28 | 676d |  |  | G4 | 10816h | 10816h | TAPS-Conf | Torben Themsen |  | Rel-6 |  |  |  |  |
| 267 | 39.2.1 | Deleted at TSG #27 - 51.010-1 Add testing |  | 676d | 2002-06-28 A | 2005-01-28 A | 100% |  | 2002-06-28 | 2005-01-28 | 676d |  | finish no earlier than 2005-01-28 | G4 | 5408h | 5408h |  |  |  | Rel-6 |  |  |  |  |
| 268 | 40 | **Seamless support of streaming services in A/Gb mode** |  | 1425d? | 2000-01-03 A | 2005-06-17 | 99% | 17.86d? | 2000-01-03 | 2005-01-28 | 1325d? | 140d |  | GP | 53088h | 52302.5h | SSStrea | José Luis Carrizo Martínez, Vodafone |  | Rel-6 | TSG | Paolo |  |  |
| 269 | 40.1 | **Identification of requirements for streaming** |  | 46d? | 2003-06-27 A | 2003-08-29 A | 100% |  | 2003-06-27 | 2003-08-29 | 46d? |  |  | G1 | 736h | 736h |  |  |  | Rel-6 |  |  |  |  |
| 270 | 34.1.1 | Requirements |  | 46d? | 2003-06-27 A | 2003-08-29 A | 100% |  | 2003-06-27 | 2003-08-29 | 46d? |  | finish no earlier than 2003-08-29 | G1 | 368h | 368h |  |  |  | Rel-6 |  |  |  |  |

Notes:
- 246: Approved at SA#14. This may require BBs from CN1, CN4, SA5 and T3 / Text3: 33.102
- 247: Contribution received S3#24, S3#25
- 249: Finished in CN4#26
- 251: Updated according to SP-040420
- 252: CN#25: Updated WID NP-040351 replaces NP-040144. / Text3: 22.127, 23.198, 29.198, 29.199, 29.998
- 254: Inherited by CN5 from SA2 at TSG#25 Sep 2004. SA2's 23.127 (OSA/VHE Stage 2) replaced from Rel-6 onwards by a new CN5 TS 23.198 (Stage 2 OSA-only). / Text3: 23.198 OSA Stage 2-ONLY replaces 23.127 (OSA/VHE) from Rel-6 onwards
- 255: Text3: 29.198-15
- 256: Text3: 29.198, 29.998
- 257: N5#26: Split WI into TS & TR. / Text3: 29.198-14
- 258: Text3: 29.199
- 259: Text3: 29.198, 29.998
- 260: Text3: 29.198, 29.998
- 261: TSG#25 Approved CN5 29.199 Parlay X Web services. Ongoing 3GPP/OMA co-ordination to avoid OMA producing conflicting/OVERLAPING specs (NP-040283/SP-040493).
- 262: N5#26:TR Completion 09/04; consistent with CN1 delayed Rel-6 completion.
- 264: Ready
- 266: DELETE
- 267: DELETE
- 269: Started

| ID | WBS | Task | Duration | Start | Finish | Complete | Remaining | Baseline start | Baseline finish | Baseline duration | Total slack | Constraint | Resources | Work | Actual work | Text6 | Text3 | Text4 | Text5 | Text8 | Text1 | Text7 | Text2 |
| --- | --- | --- | --- | --- | --- | --- | --- | --- | --- | --- | --- | --- | --- | --- | --- | --- | --- | --- | --- | --- | --- | --- | --- |
| 271 | 40.2 | **Performance study of cell change mechanisms** | 955d? | 2000-01-03 A | 2003-08-29 A | 100% |  | 2000-01-03 | 2003-08-29 | 955d? |  |  | G1 | 30560h | 30560h | Rel-6 |  |  |  |  |  |  |  |
| 272 | 34.2.1 | Performance of NACC | 955d? | 2000-01-03 A | 2003-08-29 A | 100% |  | 2000-01-03 | 2003-08-29 | 955d? |  | finish no earlier than 2003-08-29 | G1 | 7640h | 7640h | Rel-6 |  |  |  |  |  |  |  |
| 273 | 34.2.2 | Performance of cell change in DTM for the PS domain | 955d? | 2000-01-03 A | 2003-08-29 A | 100% |  | 2000-01-03 | 2003-08-29 | 955d? |  | finish no earlier than 2003-08-29 | G1 | 7640h | 7640h | Rel-6 |  |  |  |  |  |  |  |
| 274 | 34.2.3 | Handover | 955d? | 2000-01-03 A | 2003-08-29 A | 100% |  | 2000-01-03 | 2003-08-29 | 955d? |  | finish no earlier than 2003-08-29 | G1 | 7640h | 7640h | Rel-6 |  |  |  |  |  |  |  |
| 275 | 40.3 | **Reduction of service interruption times and packet loss during mobility procedures** | 516d? | 2003-06-27 A | 2005-06-17 | 93% | 34.03d? | 2003-06-27 | 2003-11-21 | 106d? | 140d |  | G2 | 10800h | 10087.8h | Rel-6 |  |  |  |  |  |  |  |
| 276 | 34.3.1 | Optimisations of existing mechanisms/procedures | 106d? | 2003-06-27 A | 2003-11-21 A | 100% |  | 2003-06-27 | 2003-11-21 | 106d? |  | finish no earlier than 2003-11-21 | G2 | 848h | 848h | Rel-6 |  |  |  |  |  |  |  |
| 277 | 34.3.2 | Inter-system NACC | 106d? | 2003-06-27 A | 2003-11-21 A | 100% |  | 2003-06-27 | 2003-11-21 | 106d? |  | finish no earlier than 2003-11-21 | G2 | 848h | 848h | Rel-6 |  |  |  |  |  |  |  |
| 278 | 34.3.3 | PS Handover (within GERAN and between GERAN and UTRAN) | 516d? | 2003-06-27 A | 2005-06-17 | 89% | 55d? | 2003-06-27 | 2003-11-21 | 106d? | 140d | finish no earlier than 2003-11-21 | G2 | 4128h | 3688h | Rel-6 |  |  |  |  |  |  |  |
| 279 | 34.3.4 | Dependency to other features | 106d? | 2003-06-27 A | 2003-11-21 A | 100% |  | 2003-06-27 | 2003-11-21 | 106d? |  | finish no earlier than 2003-11-21 | G2 | 848h | 848h | Rel-6 |  |  |  |  |  |  |  |
| 280 | 40.5 | **MS conformance testing** | 31d? | 2003-12-19 A | 2004-01-30 A | 100% |  | 2003-12-19 | 2004-01-30 | 31d? |  |  | G3 | 248h | 248h | Rel-6 |  |  |  |  |  |  |  |
| 281 | 34.4.1 | MS conformance tests | 31d? | 2003-12-19 A | 2004-01-30 A | 100% |  | 2003-12-19 | 2004-01-30 | 31d? |  | finish no earlier than 2004-01-30 | G4,G5 | 248h | 248h | Rel-6 |  |  |  |  |  |  |  |
| 282 | 34.5 | GERAN A/Gb mode security enhancements | 612d? | 2002-09-26 A | 2005-01-28 A | 100% |  | 2002-09-26 | 2005-01-28 | 612d? |  | finish no earlier than 2005-01-28 | S3 | 4896h | 4896h | Rel-6 | 33.102 | Peter Howard, Vodafone | peter.howard@vodafone.com | Maurice |  |  |  |
| 283 | 41 | Performance characterisation of default codecs for PS conversational multimedia application | 455d | 2002-09-13 A | 2004-06-10 A | 100% |  | 2002-09-13 | 2004-06-10 | 455d |  | finish no earlier than 2004-06-10 | S4 | 3640h | 3640h | Rel-6 | TR 26.935 | Pasi Ojala (Nokia) | pasi.s.ojala@nokia.com | Paolo | CODCAR | TSG |  |
| 284 | 43 | Study on Privacy Capability | 83d | 2003-11-10 A | 2004-03-03 A | 100% |  | 2003-11-10 | 2004-03-03 | 83d |  | start no earlier than 2003-11-10 | S1 | 664h | 664h | Rel-6 | TR 21.949 | Liz Daniel, Lucent |  | Michael | PrivCap | TSG |  |
| 285 | 44 | **OAM&P Rel-6** | 652d? | 2002-09-12 A | 2005-03-11 A | 100% |  | 2002-09-12 | 2005-03-11 | 652d? |  |  | S5 | 30819.5h | 30819.5h |  | 32-series | Michael TRUSS (Motorola) | Michael.Truss@MOTOROLA.COM | Adrian | OAM | TSG |  |
| 286 | 44.1 | Principles, high level Requirements and Architecture | 526d | 2002-09-12 A | 2004-09-16 A | 100% |  | 2002-09-12 | 2004-09-16 | 526d |  | finish no earlier than 2004-09-16 | S5 | 4208h | 4208h | Rel-6 | 32.101, 32.102 | Michael TRUSS (Motorola) | Michael.Truss@MOTOROLA.COM |  | OAM-AR | TSG | BCaM |
| 287 | 44.2 | Performance Management | 591d | 2002-09-12 A | 2004-12-16 A | 100% |  | 2002-09-12 | 2004-12-16 | 591d |  | finish no earlier than 2004-12-16 | S5 | 4728h | 4728h | Rel-6 | 32.401/3, 52.402, 32.411/2/3, 32.432/5/6 | Christian TOCHE (Nortel Networks) | toche@NORTELNETWORKS.COM |  | OAM-PM | TSG | BCaM |
| 288 | 44.4 | Network Infrastructure Management | 591d | 2002-09-12 A | 2004-12-16 A | 100% |  | 2002-09-12 | 2004-12-16 | 591d |  | finish no earlier than 2004-12-16 | S5 | 4728h | 4728h | Rel-6 | 32.15x, 32.3/6/7xy | Thomas TOVINGER (Ericsson) | Thomas.Tovinger@emw.ericsson.se |  | OAM-NIM | TSG |  |
| 289 | 44.5 | **Trace Management Rel-6** | 646d? | 2002-09-20 A | 2005-03-11 A | 100% |  | 2002-09-20 | 2005-03-11 | 646d? |  |  | S5 | 12061.9h | 12061.9h | Rel-6 | 32.42x, 52.008 | Kari RÖNKÄ (Nokia) | kari.t.ronka@nokia.com |  | OAM-Trace | TSG |  |
| 290 | 37.4.1 | Subscriber and UE trace management | 585d | 2002-09-20 A | 2004-12-16 A | 100% |  | 2002-09-20 | 2004-12-16 | 585d |  | finish no earlier than 2004-12-16 | S5 | 4680h | 4680h | Rel-6 | 32.421/2/3, 52.008 | Kari RÖNKÄ (Nokia) | kari.t.ronka@nokia.com |  | OAM-Trace | TSG |  |
| 291 | 37.4.2 | Subscriber and equipment trace in UTRAN | 268d? | 2003-06-06 A | 2004-06-15 A | 100% |  | 2003-06-06 | 2004-06-15 | 268d? |  | finish no earlier than 2004-06-15 | R3 | 2144h | 2144h | Rel-6 | TS25.413, 25.420, 25.423 | Yann Sehedi, Nortel | sehedic@nortelnetworks.com | MCC_RAN | OAM-Trace-RAN | TSG |  |
| 292 | 37.4.3 | Trace Management, Stage3 | 193.74d? | 2004-06-09 A | 2005-03-11 A | 100% |  | 2004-06-09 | 2005-03-11 | 193.74d? |  | finish no earlier than 2005-03-11 | N4 | 1549.92h | 1549.92h | Rel-6 | TS 23.205, 29.232, 29.060, 29.002, 29.228 | Seppo Kauntola ( Nokia Corporation) | seppo.kauntola@nokia.com |  | OAM-Trace | TSG |  |
| 293 | 38 | **Charging Management** | 666d? | 2002-11-21 A | 2005-06-09 | 99% | 7.35d? | 2002-11-21 | 2005-06-09 | 666d? | 146d |  | S5 | 55320h | 51141.3h | Rel-6 | 32.2xy | Karl-Heinz NENNER (T-Mobile) | karl-heinz.nenner@t-mobile.de | Adrian | CH | TSG |  |
| 294 | 38.1 | Charging architecture and principles | 390d? | 2003-03-21 A | 2004-09-16 A | 100% |  | 2003-03-21 | 2004-09-16 | 390d? |  | start no earlier than 2003-03-21 | S5 | 3120h | 3120h | Rel-6 | 32.240 |  |  |  | CH | TSG |  |
| 295 | 38.2 | Charging Data Record (CDR) file format and transfer | 260d? | 2003-03-21 A | 2004-03-18 A | 100% |  | 2003-03-21 | 2004-03-18 | 260d? |  | start no earlier than 2003-03-21 | S5 | 2080h | 2080h | Rel-6 | 32.297 |  |  |  | CH | TSG |  |
| 296 | 38.3 | CDR parameter description | 580d? | 2003-03-21 A | 2005-06-09 | 95% | 29d? | 2003-03-21 | 2005-06-09 | 580d? | 146d | finish no earlier than 2005-06-09 | S5 | 4640h | 4408h | Rel-6 | 32.298 |  |  |  | CH | TSG |  |
| 297 | 38.4 | Diameter charging applications | 390d? | 2003-03-21 A | 2004-09-16 A | 100% |  | 2003-03-21 | 2004-09-16 | 390d? |  | start no earlier than 2003-03-21 | S5 | 3120h | 3120h | Rel-6 | 32.299 |  |  |  | CH | TSG |  |
| 298 | 38.5 | Online Charging System (OCS) architecture study | 130d? | 2003-03-21 A | 2003-09-18 A | 100% |  | 2003-03-21 | 2003-09-18 | 130d? |  | start no earlier than 2003-03-21 | S5 | 1040h | 1040h | Rel-6 | 32.815 |  |  |  | CH | TSG |  |
| 299 | 38.6 | OCS: Applications and interfaces | 455d? | 2003-03-21 A | 2004-12-16 A | 100% |  | 2003-03-21 | 2004-12-16 | 455d? |  | start no earlier than 2003-03-21 | S5 | 3640h | 3640h | Rel-6 | 32.296 |  |  |  | CH | TSG |  |

Notes:
- 271: Started
- 275: Completed at GERAN#17
- 280: Closed, no work needed
- 281: Closed, no work needed
- 282: Possible changes to 33.102 or new specification needed.
- 285: SA#26: Updated WID SP-040766 was SP-020445. Completion delayed 12/04->03/05 due to OAM-Trace in CN1/4.
- 286: SA#26: Updated WID SP-040767 was SP-020446
- 287: SA#26: Updated WID SP-040782 was SP-020499
- 288: SA#26: Updated WID SP-040789 was SP-020754
- 289: TSG#26: SA#26: Updated WID SP-040782 was SP-020499. SA5 completed 12/04. Signalling Based Trace Activation for IMS (SIP) moved to Rel-7. Reason: CN1 cannot complete 24.229 trace without IETF dependency => estimate 05/2005.
- 290: TSG#26: Approved 32.423/52.008. SA5 work completed 12/2004.
- 293: SA#26: Updated WID SP-040773 was SP-030047. Target 06/2005 for WLAN/PoC/MBMS Charging 32.252/72/73/98
- 294: SA#25 09/2004 completed
- 295: SA#23 03/2004 completed
- 296: Target SA#27 03/2005 completed
- 297: SA#25 09/2004 completed
- 298: SA#21 09/2003 completed
- 299: SA#26 12/2004 completed

| ID | WBS | Task | Duration | Start | Finish | Complete | Remaining | Baseline start | Baseline finish | Baseline duration | Total slack | Constraint | Resources | Work | Actual work | Text1 | Text4 | Text6 | Text7 | Text10 | Text5 | Text2 | Text8 | Text9 |
| --- | --- | --- | --- | --- | --- | --- | --- | --- | --- | --- | --- | --- | --- | --- | --- | --- | --- | --- | --- | --- | --- | --- | --- | --- |
| 300 | 38.7 | **Charging Management for Bearer level** | 390d? | 2003-03-21 A | 2004-09-16 A | 100% |  | 2003-03-21 | 2004-09-16 | 390d? |  |  | S5 | 11440h | 11440h | CH-BC | Benni ALEXANDER (Nokia) | Rel-6 | TSG |  |  |  |  |  |
| 301 | 38.7.1 | CS domain charging | 260d? | 2003-03-21 A | 2004-03-18 A | 100% |  | 2003-03-21 | 2004-03-18 | 260d? |  | start no earlier than 2003-03-21 | S5 | 2080h | 2080h | CH |  | Rel-6 | TSG |  |  |  |  |  |
| 302 | 38.7.2 | PS domain charging | 390d? | 2003-03-21 A | 2004-09-16 A | 100% |  | 2003-03-21 | 2004-09-16 | 390d? |  | start no earlier than 2003-03-21 | S5 | 3120h | 3120h | CH |  | Rel-6 | TSG |  |  |  |  |  |
| 303 | 38.7.3 | CDR transfer | 390d? | 2003-03-21 A | 2004-09-16 A | 100% |  | 2003-03-21 | 2004-09-16 | 390d? |  | start no earlier than 2003-03-21 | S5 | 3120h | 3120h | CH |  | Rel-6 | TSG |  |  |  |  |  |
| 304 | 38.8 | Charging Management for the IMS | 455d? | 2003-03-21 A | 2004-12-16 A | 100% |  | 2003-03-21 | 2004-12-16 | 455d? |  | finish no earlier than 2004-12-16 | S5 | 3640h | 3640h | IMS2-CH | Patrik TEPPO (Ericsson) | Rel-6 | TSG |  |  |  |  |  |
| 305 | 38.9 | Charging Management for the Service domain | 580d? | 2003-03-21 A | 2005-06-09 | 95% | 29d? | 2003-03-21 | 2005-06-09 | 580d? | 146d | finish no earlier than 2005-06-09 | S5 | 4640h | 4408h | CH | Gerald GÖRMER (Siemens) | Rel-6 | TSG |  |  |  |  |  |
| 306 | 38.10 | **Overall architectural aspects of IP flow based bearer level charging** | 602d? | 2002-11-21 A | 2005-03-11 A | 100% |  | 2002-11-21 | 2005-03-11 | 602d? |  |  | S2 | 12632h | 12632h | CH-FBC |  | Rel-6 |  |  |  |  |  |  |
| 307 | 38.10.1 | Overall definition of FBC architecture | 334d? | 2002-11-21 A | 2004-03-02 A | 100% |  | 2002-11-21 | 2004-03-02 | 334d? |  | start no earlier than 2002-11-21 | S2 | 2672h | 2672h |  |  | Rel-6 |  | SP-24 |  |  |  |  |
| 308 | 38.10.2 | Study on providing policy control with FBC | 130d? | 2004-02-02 A | 2004-07-30 A | 100% |  | 2004-02-02 | 2004-07-30 | 130d? |  | start no earlier than 2004-02-01 | S2 | 1040h | 1040h |  |  | Rel-6 |  | SP-24 |  |  |  |  |
| 309 | 38.10.3 | Gx interface for flow based charging | 223d? | 2004-02-02 A | 2004-12-08 A | 100% |  | 2004-02-02 | 2004-12-08 | 223d? |  | start no earlier than 2004-02-01 | N3 | 1784h | 1784h | CH-FBC | Juha Räsänen (Nokia) | Rel-6 | TSG | SP-25 | juha.a.rasanen@nokia.com |  |  |  |
| 310 | 38.10.4 | Rx interface for flow based charging | 290d? | 2004-02-02 A | 2005-03-11 A | 100% |  | 2004-02-02 | 2005-03-11 | 290d? |  | finish no earlier than 2005-03-11 | N3 | 2320h | 2320h | CH-FBC | Javier Gonzalez Gallego | Rel-6 | TSG | SP-25 | ggfj@nortelnetworks.com |  |  |  |
| 311 | 13 | **Rel-6 UICC/USIM enhancements and interworking** | 1164d? | 2000-09-25 A | 2005-03-10 A | 100% |  | 2000-09-25 | 2005-03-10 | 1164d? |  |  | T3 | 43088h | 43088h | USAT1 |  | Rel-6 | TSG |  |  | Ter | Claus | 1800 |
| 312 | 13.1 | **UICC API** | 777d | 2002-03-20 A | 2005-03-10 A | 100% |  | 2002-03-20 | 2005-03-10 | 777d |  |  | T3 | 15024h | 15024h | USAT1-API |  | Rel-6 |  |  |  | Ter |  | 1802 |
| 313 | 13.1.1 | Java API Test specification | 59d | 2002-03-20 A | 2002-06-10 A | 100% |  | 2002-03-20 | 2002-06-10 | 59d |  | finish no earlier than 2002-09-20 | T3 | 472h | 472h |  | Mario Pérez (Microelectrónica Española) | Rel-6 |  |  |  |  |  |  |
| 314 | 13.1.2 | Deleted - Java API Test specification (TS 43.019 Rel-5) | 268d | 2002-05-30 A | 2003-06-09 A | 100% |  | 2002-05-30 | 2003-06-09 | 268d |  | finish no earlier than 2003-09-17 | T3 | 2144h | 2144h |  | Mario Pérez (Microelectrónica Española) | Rel-6 |  |  |  |  |  |  |
| 315 | 39.1.3 | 2G/3G Java Card™ API based applet interworking | 255d | 2003-03-17 A | 2004-03-05 A | 100% |  | 2003-03-17 | 2004-03-05 | 255d |  | finish no earlier than 2004-02-19 | T3 | 2040h | 2040h | USAT1-API | Stéphane Andrau-Oberthur Card Systems | Rel-6 | TSG |  |  |  |  |  |
| 316 | 39.1.4 | (U)SIM API for Java Card Testing Work Item | 519d | 2003-03-17 A | 2005-03-10 A | 100% |  | 2003-03-17 | 2005-03-10 | 519d |  | finish no earlier than 2005-03-10 | T3 | 4152h | 4152h |  | Christophe Begassat (Axalto) | Rel-6 | TSG |  | 'cbegassat@axalto.com' |  | Friedhelm |  |
| 317 | 39.2 | **Rel-6 USIM toolkit enhancements** | 1160d? | 2000-09-25 A | 2005-03-04 A | 100% |  | 2000-09-25 | 2005-03-04 | 1160d? |  |  | T3 | 21848h | 21848h |  |  | Rel-6 |  |  |  |  | Claus |  |
| 318 | 39.2.1 | **C SIM API** | 525d | 2000-09-25 A | 2002-09-27 A | 100% |  | 2000-09-25 | 2002-09-27 | 525d |  |  | T3 | 9960h | 9960h | USAT1-API-MULTOS |  | Rel-6 | TSG |  |  | Ter |  | 2031 |
| 319 | 39.2.1.1 | Specification | 525d | 2000-09-25 A | 2002-09-27 A | 100% |  | 2000-09-25 | 2002-09-27 | 525d |  | finish no earlier than 2002-09-27 | T3 | 4200h | 4200h |  | Neil Livingston – Aspects Software | Rel-6 | TSG |  |  | Ter |  | 2032 |
| 320 | 39.2.1.2 | Test specification | 195d | 2001-01-01 A | 2001-09-28 A | 100% |  | 2001-01-01 | 2001-09-28 | 195d |  | finish no earlier than 2001-09-28 | T3 | 1560h | 1560h |  | Neil Livingston – Aspects Software | Rel-6 | TSG |  |  | Ter |  | 2033 |
| 321 | 39.2.2 | USIM application toolkit Conformance Test Specification for Mobile Equipments | 326d? | 2003-12-05 A | 2005-03-04 A | 100% |  | 2003-12-05 | 2005-03-04 | 326d? |  | start no earlier than 2003-12-05 | T3 | 2608h | 2608h |  | Eric Laffont, Gemplus | Rel-6 | TSG |  | Eric.laffont@gemplus.com |  |  |  |
| 322 | 40 | **Packet Switched Streaming Services Rel-6** | 668d? | 2002-11-18 A | 2005-06-08 | 98% | 11.8d? | 2002-11-18 | 2005-03-17 | 609d? | 147d |  | S4 | 10539.4h | 10435.5h | PSSrel6 | Olle Franceschi (Ericsson) | Rel-6 | TSG |  | olle.franceschi@ericsson.com |  | Paolo |  |
| 323 | 40.1 | Stage 1 | 86d? | 2002-11-18 A | 2003-03-17 A | 100% |  | 2002-11-18 | 2003-03-17 | 86d? |  | finish no earlier than 2003-03-17 | S1 | 688h | 688h |  |  | Rel-6 | TSG |  |  |  |  |  |
| 324 | 40.2 | Stage 3 | 649d? | 2002-12-13 A | 2005-06-08 | 98% | 12.98d? | 2002-12-13 | 2005-03-17 | 590d? | 147d | finish no earlier than 2005-06-08 | S4 | 5192h | 5088.16h | PSSrel6-Stage3 | Olle Franceschi (Ericsson) | Rel-6 | WG |  | olle.franceschi@ericsson.com |  | Paolo |  |
| 325 | 41 | AMR-WB extension for high audio quality | 649d | 2002-12-13 A | 2005-06-08 | 98% | 12.98d | 2002-12-13 | 2005-03-17 | 590d | 147d | finish no earlier than 2005-06-08 | S4 | 5192h | 5088.16h | AMRWB+ | Janne Vainio (Nokia) | Rel-6 | TSG |  | janne.m.vainio@nokia.com |  | Paolo |  |
| 326 | 42 | Codec Enhancements for Packet Switched Conversational Multimedia Applications | 198d? | 2004-03-16 A | 2004-12-16 A | 100% |  | 2004-03-16 | 2004-12-16 | 198d? |  | finish no earlier than 2004-12-16 | S4 | 1584h | 1584h | CEPSCM | Miska Hannuksela (Nokia) | Rel-6 | WG |  | miska.hannuksela@nokia.com |  | Paolo |  |
| 327 | 43 | 3G-324M Improvements | 198d? | 2004-03-16 A | 2004-12-16 A | 100% |  | 2004-03-16 | 2004-12-16 | 198d? |  | finish no earlier than 2004-12-16 | S4 | 1584h | 1584h | 3G-324MI | Bo Burman, Ericsson | Rel-6 | WG |  | bo.burman@ericsson.com |  | Paolo |  |
| 328 | 44 | Single Antenna Receiver Interference Cancellation (SAIC) | 420.92d? | 2002-11-15 A | 2004-08-27 A | 100% |  | 2002-11-15 | 2004-08-27 | 420.92d? |  | finish no earlier than 2004-08-27 | GP; G1 | 6734.72h | 6734.72h | SAIC | Marc Grant, Cingular Wireless | Rel-6 | TSG |  |  |  | Paolo |  |

Notes:
- 301: SA#23 03/2004 completed / Text3: 32.250
- 302: SA#25 09/2004 completed / Text3: 32.251
- 303: SA#25 09/2004 completed / Text3: 32.295
- 304: SA#26 12/2004 completed / Text3: 32.260
- 305: SA#26: Updated WID SP-040778 was SP-030050. Target completion 06/2005. Consisting of MMS-CH, LCS-CH, WLAN-CH, POC-CH, MBMS-CH / Text3: 32.252, 32.270/1/2
- 306: Text3: 23.125
- 309: Text3: 29.210
- 310: Text3: 29.209
- 312: 8/3/2001: test spec is based on R99 core spec, so deleted from Workplan
- 314: MOVED to Rel-5 WP
- 316: Text3: 31.213
- 321: Text3: 31.124
- 323: 2nd resp SA4 / Text3: 22.233
- 324: TR tbc by Sept. 05 / Text3: 26.233, 26.234, 26.244, 26.245, 26.246, 26.401, 26.402, 26.403, 26.404, 26.405, 26.406, 26.410, 26.411, 26.412, 26.273, 26.290, 26.304, 26.412, 26.274, 26.936
- 325: TR tbc by Sept. 05 / Text3: 26.290, 26.304, 26.273, 26.274, 26.412, 26.936
- 326: Completed / Text3: 26.235, 26.236
- 327: Completed / Text3: 26.111, 26.911

| ID | WBS | Task | Type | Duration | Start | Finish | Complete | Remaining | Baseline start | Baseline finish | Baseline duration | Total slack | Constraint | Resources | Work | Actual work | Text1 | Text4 | Text5 | Text6 | Text7 | Text8 | Text3 |
| --- | --- | --- | --- | --- | --- | --- | --- | --- | --- | --- | --- | --- | --- | --- | --- | --- | --- | --- | --- | --- | --- | --- | --- |
| 329 | 45 | **DELETE - Support of Conversational Services in A/Gb mode via the PS domain** |  | 64d? | 2003-11-21 | 2004-02-19 |  |  | 2003-02-07 | 2005-11-11 | 721d? | 486d |  | GP |  |  | SCSAGB | David Bladsjö, Ericsson | david.bladsjo@ericsson.com | Rel-6 | TSG | Paolo |  |
| 330 | 45.1 | Delete - Creation of a TR | milestone | 0d? | 2003-11-21 | 2003-11-21 |  |  | 2003-02-07 | 2003-11-21 | 206d? | 550d | start no earlier than 2003-11-21 | GP |  |  | SCSAGB-TR | David Bladsjö, Ericsson |  | Rel-6 | TSG |  |  |
| 331 | 45.2 | Delete - Stage 2 | milestone | 0d? | 2003-11-21 | 2003-11-21 |  |  | 2003-11-21 | 2005-01-28 | 311d? | 550d | finish no earlier than 2003-11-21 | GP |  |  | SCSAGB-Stage2 | David Bladsjö, Ericsson |  | Rel-6 | TSG |  |  |
| 332 | 45.3 | Delete - Radio Channel Support | milestone | 0d? | 2003-11-21 | 2003-11-21 |  |  | 2004-02-06 | 2005-11-11 | 461d? | 550d | finish no earlier than 2003-11-21 | GP |  |  | SCSAGB-RCS | David Bladsjö, Ericsson |  | Rel-6 | TSG |  |  |
| 333 | 45.4 | Delete - Definition of radio resource management functionality | milestone | 0d? | 2003-11-21 | 2003-11-21 |  |  | 2004-02-06 | 2005-11-11 | 461d? | 550d | finish no earlier than 2003-11-21 | GP; G2 |  |  | SCSAGB-RRM | David Bladsjö, Ericsson |  | Rel-6 | TSG |  |  |
| 334 | 45.5 | Delete, replaced by 50561 - PS Handover | milestone | 0d | 2003-11-21 | 2004-02-19 |  |  | 2004-02-06 | 2005-01-28 | 256d? | 486d | start no earlier than 2003-11-21 | GP; GP; N1 |  |  | SCSAGB-PSH | David Bladsjö, Ericsson |  | Rel-6 | TSG |  |  |
| 335 | 45.6 | Delete - Modifications to FLO | milestone | 0d? | 2003-11-21 | 2003-11-21 |  |  | 2004-02-06 | 2005-11-11 | 461d? | 550d | finish no earlier than 2003-11-21 | GP; G2 |  |  | SCSAGB-FLO | David Bladsjö, Ericsson |  | Rel-6 | TSG |  |  |
| 336 | 46 | **Enhancement of dialled service for CAMEL** |  | 199d | 2003-03-28 A | 2003-12-31 A | 100% |  | 2003-03-28 | 2003-12-31 | 199d |  |  | S1 | 3184h | 3184h | EDCAMEL | Craig Bishop, Samsung Electronics Research Institute |  | Rel-6 | TSG | Andrijana |  |
| 337 | 46.1 | Stages 2 and 3 |  | 199d | 2003-03-28 A | 2003-12-31 A | 100% |  | 2003-03-28 | 2003-12-31 | 199d |  | finish no earlier than 2003-09-19 | N4 | 1592h | 1592h |  |  |  | Rel-6 |  |  |  |
| 338 | 47 | Bandwidth and resource savings in CS networks |  | 273d? | 2003-06-01 A | 2004-06-16 A | 100% |  | 2003-06-01 | 2004-06-16 | 273d? |  | finish no earlier than 2004-06-16 | S2 | 2184h | 2184h | BARS |  |  | Rel-6 |  | Sang-Ui | 23.977 |
| 339 | 48 | FS on (U)SIM Security Reuse by Peripheral Devices on Local Interfaces |  | 127d? | 2003-07-03 A | 2003-12-26 A | 100% |  | 2003-07-03 | 2003-12-26 | 127d? |  | finish no earlier than 2003-12-26 | S3 | 1016h | 1016h |  | Raziq Yaqub, Toshiba America Research Inc. | ryaqub@tari.toshiba.com | Rel-6 | TSG | Maurice |  |
| 340 | 49 | **Multiple TBF in A/Gb mode** |  | 736d? | 2002-04-05 A | 2005-01-28 | 99% | 0d? | 2002-04-05 | 2005-01-28 | 736d? | 0d |  | GP; G2 | 35200h | 27408.6h | MULTBF | Gunnar Mildh, Ericsson |  | Rel-6 | TSG | Paolo |  |
| 341 | 49.1 | **Multiple TBF in A/Gb mode** |  | 366d? | 2002-04-05 A | 2003-08-29 A | 100% |  | 2002-04-05 | 2003-08-29 | 366d? |  |  | GP; G2 | 23424h | 23424h | MULTBF-Agbmode | Gunnar Mildh, Ericsson |  | Rel-6 | TSG |  |  |
| 342 | 49.1.1 | Multiple TBF Concept paper |  | 366d? | 2002-04-05 A | 2003-08-29 A | 100% |  | 2002-04-05 | 2003-08-29 | 366d? |  | finish no earlier than 2003-08-29 | GP; G2 | 5856h | 5856h |  |  |  | Rel-6 |  |  |  |
| 343 | 49.1.2 | Multiple TBF Stage 2 (43.064) CRs |  | 366d? | 2002-04-05 A | 2003-08-29 A | 100% |  | 2002-04-05 | 2003-08-29 | 366d? |  | finish no earlier than 2003-08-29 | GP; G2 | 5856h | 5856h |  |  |  | Rel-6 |  |  |  |
| 344 | 49.1.3 | Multiple TBF Stage 3 (44.060) CRs |  | 366d? | 2002-04-05 A | 2003-08-29 A | 100% |  | 2002-04-05 | 2003-08-29 | 366d? |  | finish no earlier than 2003-08-29 | GP; G2 | 5856h | 5856h |  |  |  | Rel-6 |  |  |  |
| 345 | 49.2 | Deleted at TGS # 27 - Multiple TBF in A/Gb mode – MS testing | milestone | 0d? | 2005-01-28 A | 2005-01-28 A | 100% |  | 2005-01-28 | 2005-01-28 | 0d? |  | start no earlier than 2005-01-28 | G3 |  |  | MULTBF-Testing | Gunnar Mildh, Ericsson |  | Rel-6 | TSG | Paolo |  |
| 346 | 50 | **Alignment between the test-regimes for GERAN capable MS** |  | 526d? | 2003-08-29 A | 2005-09-02 | 80% | 105.2d? | 2003-08-29 | 2005-01-28 | 371d? | 85d |  | G3 | 8416h | 3366.4h | ALTERE | Toubassi, Ericsson |  | Rel-6 | TSG | Stoyan |  |
| 347 | 50.1 | Determine the controversial test cases in the different test regimes and align them with 3GPP GERAN test specifications. Such test cases to be added to TS 51.010. |  | 526d? | 2003-08-29 A | 2005-09-02 | 80% | 105.2d? | 2003-08-29 | 2005-01-28 | 371d? | 85d | finish no earlier than 2005-09-02 | G3 | 4208h | 3366.4h | ALTERE-TC |  |  | Rel-6 | TSG |  |  |
| 348 | 51 | Addition of U-TDOA in the CS domain |  | 111d? | 2003-11-21 A | 2004-04-23 A | 100% |  | 2003-11-21 | 2004-04-23 | 111d? |  | finish no earlier than 2004-04-23 | GP | 888h | 888h | UTDOACS | Bob Gross, Rhys Robinson, TruePosition, Inc. | rlgross@trueposition.com | Rel-6 | TSG | Paolo |  |
| 349 | 52 | Addition of U-TDOA in the PS domain |  | 361d? | 2003-06-27 A | 2004-11-12 A | 100% |  | 2003-06-27 | 2004-11-12 | 361d? |  | finish no earlier than 2004-11-12 | GP | 2888h | 2888h | UTDOAPS | Bob Gross, Rhys Robinson, TruePosition, Inc. | rlgross@trueposition.com | Rel-6 | TSG | Paolo |  |
| 350 | 53 | **Downlink Advanced Receiver Performance** |  | 466d? | 2003-11-21 A | 2005-09-02 | 93% | 32.47d? | 2003-11-21 | 2005-02-28 | 332d? | 85d |  | GP | 19160h | 13006.1h | DARP | Tommy Bysted, Nokia | tommy.bysted@nokia.com | Rel-6 | TSG | Paolo |  |
| 351 | 53.1 | DARP test scenarios |  | 201d? | 2003-11-21 A | 2004-08-27 A | 100% |  | 2003-11-21 | 2004-08-27 | 201d? |  | finish no earlier than 2004-08-27 | GP | 1608h | 1608h | DARP-TS | Tommy Bysted, Nokia | tommy.bysted@nokia.com | Rel-6 | TSG | Paolo |  |
| 352 | 53.2 | **DARP for GMSK modulated voice services** |  | 201d? | 2004-02-06 A | 2004-11-12 | 99% | 0d? | 2004-02-06 | 2004-11-12 | 201d? | 0d |  | GP | 4824h | 3216h | DARP-GMSK | Tommy Bysted, Nokia | tommy.bysted@nokia.com | Rel-6 | TSG | Paolo |  |
| 353 | 53.2.1 | Performance requirements in 45.005 |  | 201d? | 2004-02-06 A | 2004-11-12 A | 100% |  | 2004-02-06 | 2004-11-12 | 201d? |  | finish no earlier than 2004-11-12 | GP | 1608h | 1608h | DARP-GMSK-Perf |  |  | Rel-6 | TSG |  |  |
| 354 | 53.2.2 | Radio subsystem link control in 45.008 |  | 201d? | 2004-02-06 A | 2004-11-12 A | 100% |  | 2004-02-06 | 2004-11-12 | 201d? |  | finish no earlier than 2004-11-12 | GP | 1608h | 1608h | DARP-GMSK-LC |  |  | Rel-6 | TSG |  |  |

Notes:
- 331: Started
- 332: Not started
- 333: Not started
- 334: Started
- 335: Not started
- 339: Approved TSG#20
- 345: DELETE
- 347: Started
- 348: Completed, except for potential LMU performance specs

| ID | WBS | Task | Type | Duration | Start | Finish | Complete | Remaining | Baseline start | Baseline finish | Baseline duration | Total slack | Constraint | Resources | Work | Actual work | Text1 | Text4 | Text5 | Text6 | Text7 | Text8 | Text3 | Text10 |
| --- | --- | --- | --- | --- | --- | --- | --- | --- | --- | --- | --- | --- | --- | --- | --- | --- | --- | --- | --- | --- | --- | --- | --- | --- |
| 355 | 53.3 | **DARP for GPRS and EGPRS MCS1-MCS4** |  | 201d? | 2004-02-06 A | 2004-11-12 A | 100% |  | 2004-02-06 | 2004-11-12 | 201d? |  |  | GP | 4824h | 4824h | DARP-GPRSE | Tommy Bysted, Nokia | tommy.bysted@nokia.com | Rel-6 | TSG | Paolo |  |  |
| 356 | 53.3.1 | Performance requirements in 45.005 |  | 201d? | 2004-02-06 A | 2004-11-12 A | 100% |  | 2004-02-06 | 2004-11-12 | 201d? |  | finish no earlier than 2004-11-12 | GP | 1608h | 1608h | DARP-GPRSE-Perf |  |  | Rel-6 | TSG |  |  |  |
| 357 | 53.3.2 | Radio subsystem link control in 45.008 |  | 201d? | 2004-02-06 A | 2004-11-12 A | 100% |  | 2004-02-06 | 2004-11-12 | 201d? |  | finish no earlier than 2004-11-12 | GP | 1608h | 1608h | DARP-GPRSE-LC |  |  | Rel-6 | TSG |  |  |  |
| 358 | 53.4 | DARP Capability signalling |  | 256d? | 2003-11-21 A | 2004-11-12 A | 100% |  | 2003-11-21 | 2004-11-12 | 256d? |  | finish no earlier than 2004-11-12 | GP | 2048h | 2048h | DARP-CAPSIG | Tommy Bysted, Nokia | tommy.bysted@nokia.com | Rel-6 | TSG | Paolo |  |  |
| 359 | 53.5 | GERAN MS Conformance test for DARP |  | 266d? | 2004-08-27 A | 2005-09-02 | 60% | 106.4d? | 2004-08-27 | 2005-02-28 | 132d? | 85d | finish no earlier than 2005-09-02 | G3 | 2128h | 1276.8h | ARP-ConfTest | Tommy Bysted, Nokia | tommy.bysted@nokia.com | Rel-6 | TSG | Michael |  |  |
| 360 | 54 | **Reduction of PS service interruption in Dual Transfer Mode** |  | 416d? | 2003-11-21 A | 2005-06-24 | 59% | 172.62d? | 2003-11-21 | 2005-01-28 | 311d? | 135d |  | G2 | 8360h | 2968.18h | PSintDTM | Toby Proctor, Siemens | toby.proctor@roke.co.uk | Rel-6 | TSG | Gert |  |  |
| 361 | 54.1 | Use case and requirement definition |  | 111d? | 2003-11-21 A | 2004-04-23 A | 100% |  | 2003-11-21 | 2004-04-23 | 111d? |  | finish no earlier than 2004-04-23 | G2 | 888h | 888h | PSintDTM-Req | Toby Proctor, Siemens | toby.proctor@roke.co.uk | Rel-6 | TSG | Gert |  |  |
| 362 | 54.2 | Performance Study of Current Procedures |  | 111d? | 2003-11-21 A | 2004-04-23 A | 100% |  | 2003-11-21 | 2004-04-23 | 111d? |  | start no earlier than 2003-11-21 | G2 | 888h | 888h | PSintDTM-Perf | Toby Proctor, Siemens | toby.proctor@roke.co.uk | Rel-6 | TSG | Gert |  |  |
| 363 | 54.3 | Reduction of service interruption times and packet loss during Dual Transfer Mode and mobility procedures |  | 146d? | 2004-04-23 A | 2004-11-12 A | 100% |  | 2004-04-23 | 2004-11-12 | 146d? |  | finish no earlier than 2004-11-12 | G2 | 1168h | 1168h | PSintDTM-Reduct | Toby Proctor, Siemens | toby.proctor@roke.co.uk | Rel-6 | TSG | Gert |  |  |
| 364 | 54.4 | MS Conformance testing |  | 261d? | 2004-06-25 | 2005-06-24 |  |  | 2004-06-25 | 2005-01-28 | 156d? | 135d | finish no earlier than 2005-06-24 | G3 | 2088h |  | PSintDTM-ConfMS |  |  | Rel-6 | TSG | Stoyan |  |  |
| 365 | 54.5 | Deleted - BTS Conformance testing | milestone | 0d? | 2005-06-24 | 2005-06-24 |  |  | 2004-06-25 | 2005-01-28 | 156d? | 135d | finish no earlier than 2005-06-24 | G3 |  |  | PSintDTM-ConfBTS |  |  | Rel-6 | TSG | Stoyan |  |  |
| 366 | 55 | CAMEL prepay interworking with SCUDIF |  | 206d | 2003-12-08 A | 2004-10-05 A | 100% |  | 2003-12-08 | 2004-10-05 | 206d |  |  | N4 | 1648h | 1648h | SCCAMEL |  |  | Rel-6 |  | Kimmo |  |  |
| 367 | 56 | **Circuit Switched Video and Voice Service Improvements** |  | 430d? | 2004-01-12 A | 2005-09-02 | 66% | 145.94d? | 2004-01-12 | 2004-12-16 | 244d? | 85d |  | S1 | 11568h | 7094h | CS_VSS | John Watson, Vodafone Group |  | Rel-6 | TSG | Michael | 23.801 |  |
| 368 | 56.1 | Stage 1 - Requirements |  | 199d | 2004-01-12 A | 2004-10-14 A | 100% |  | 2004-01-12 | 2004-10-14 | 199d |  | finish no earlier than 2004-10-14 | S1 | 1592h | 1592h | CS_VSS | John Watson, Vodafone Group |  | Rel-6 | TSG | Michael |  |  |
| 369 | 56.2 | Stage 2 Study on architecture alternatives |  | 155d? | 2004-01-12 A | 2004-08-13 A | 100% |  | 2004-01-12 | 2004-08-13 | 155d? |  | finish no earlier than 2004-08-13 | S2 | 1240h | 1240h | CS_VSS |  |  | Rel-6 |  |  |  | SP-24 |
| 370 | 56.3 | Stage 2 description on Redial |  | 164d? | 2004-05-03 A | 2004-12-16 A | 100% |  | 2004-05-03 | 2004-12-16 | 164d? |  | finish no earlier than 2004-12-16 | S2 | 1312h | 1312h | CS_VSS |  |  | Rel-6 |  |  | 23.903 | SP-24 |
| 371 | 56.4 | Deleted - GERAN2 Part |  | 430d | 2004-01-12 | 2005-09-02 |  |  | 2004-01-12 | 2004-10-14 | 199d | 85d | finish no earlier than 2005-09-02 | G2 | 3440h |  | CS_VSS |  |  | Rel-6 | TSG | Gert |  |  |
| 372 | 56.5 | Switching between voice and video call - Redial solution |  | 120d? | 2005-01-03 A | 2005-06-17 A | 100% |  |  |  |  |  | start no earlier than 2005-01-03 | C1 | 960h | 960h | CS_VSS |  |  | Rel-6 |  |  |  |  |
| 373 | 56.6 | Deleted - CN3 Part |  | 199d? | 2004-01-12 A | 2004-10-14 A | 100% |  | 2004-01-12 | 2004-10-14 | 199d? |  | finish no earlier than 2004-10-14 | N3 | 1592h | 1592h | CS_VSS |  |  | Rel-6 |  |  |  |  |
| 374 | 57 | Network Domain Security; MAP application layer security (NDS/MAPsec) |  | 127d? | 2004-07-06 A | 2004-12-29 | 20% | 101.6d? | 2004-07-06 | 2004-12-29 | 127d? | 262d | finish no earlier than 2003-12-26 | S3 | 1016h | 203.2h | MAPSEC | Peter Howard, Vodafone | Peter.Howard@vodafone.com | Rel-6 | TSG | Maurice |  |  |
| 375 | 58 | FS on Security for early IMS |  | 127d? | 2004-10-01 A | 2005-03-28 A | 100% |  | 2004-10-01 | 2005-03-28 | 127d? |  | finish no earlier than 2003-12-26 | S3 | 1016h | 1016h | SEC-IMS | Peter Howard, Vodafone | Peter.Howard@vodafone.com | Rel-6 | TSG | Maurice |  |  |
| 376 | 59 | Reorganisation of CS Data Specifications |  | 14d? | 2004-11-19 A | 2004-12-08 A | 100% |  | 2004-11-19 | 2004-12-08 | 14d? |  | finish no earlier than 2004-12-24 | N3 | 112h | 112h | CS Data | Tomas Belling(Siemens) | thomas.belling@siemens.com | Rel-6 | TSG | Seung Don |  |  |
| 377 | 60 | **Generic Access to A/Gb Interface (GAAI)** |  | 261d? | 2004-06-25 A | 2005-06-24 | 42% | 150.5d? | 2004-06-25 | 2005-06-24 | 261d? | 135d |  | GP | 6760h | 2862h | GAAI | Motorola |  | Rel-6 | TSG | Paolo |  |  |
| 378 | 60.1 | FS on GAAI |  | 46d? | 2004-06-25 A | 2004-08-27 A | 100% |  | 2004-06-25 | 2004-08-27 | 46d? |  | finish no earlier than 2004-08-27 | GP | 368h | 368h | GAAG | Motorola |  | Rel-6 | TSG | Paolo | TR 43.901 |  |
| 379 | 60.2 | GAAI – Stage 2 |  | 161d? | 2004-08-27 A | 2005-04-08 A | 100% |  | 2004-08-27 | 2005-04-08 | 161d? |  | finish no earlier than 2005-04-08 | GP | 1288h | 1288h | GAAI-Stage2 | Jari Vikberg (KI/EAB) | jari.vikberg@ericsson.com | Rel-6 | TSG | Paolo | TS 43.318 |  |
| 380 | 60.3 | GAAI – Stage 3 |  | 161d? | 2004-08-27 A | 2005-04-08 | 25% | 120.75d? | 2004-08-27 | 2005-04-08 | 161d? | 190d | finish no earlier than 2005-04-08 | GP | 1288h | 322h | GAAI-Stage3 |  |  | Rel-6 | TSG | Gert | TS 44.318 |  |
| 381 | 60.4 | MS Conformance Test for GAAI |  | 216d? | 2004-08-27 | 2005-06-24 |  |  | 2004-08-27 | 2005-06-24 | 216d? | 135d | finish no earlier than 2005-06-24 | GP | 1728h |  | GAAI-CT |  |  | Rel-6 | TSG | Michael |  |  |
| 382 | 61 | Deleted - Study of Feature Interactions Requirements | milestone | 0d? | 2004-10-01 A | 2004-10-01 A | 100% |  | 2004-10-01 | 2004-10-01 | 0d? |  | finish no earlier than 2004-10-01 | S1 |  |  | FINTER |  |  | Rel-6 |  |  |  |  |

Notes:
- 359: Started
- 361: Started
- 362: Started
- 364: Under evaluation
- 365: On-going
- 374: Approved TSG#24
- 375: Approved TSG#24. TR 33.978 Approved at TSG SA #27
- 376: Created at TSG#27 as 100 % complete
- 378: Feasibility Study
- 379: Completed
- 380: Started
- 381: Not started
- 382: SP-23 - To be abandoned?

| ID | WBS | Task | Duration | Start | Finish | Complete | Remaining | Total slack | Constraint | Resources | Work | Actual work | Text1 | Text4 | Text5 | Text6 | Text8 | Text3 |
| --- | --- | --- | --- | --- | --- | --- | --- | --- | --- | --- | --- | --- | --- | --- | --- | --- | --- | --- |
| 383 | 62 | **Support of PS Handover for GERAN A/Gb mode** | 430d? | 2003-11-03 A | 2005-06-24 | 90% | 43d? | 135d |  | GP-G2 | 13760h | 12384h | SPSHAGB | Gunnar Hedby, Ericsson | gunnar.hedby@ericsson.com | Rel-6 | Paolo |  |
| 384 | 62.1 | Stage 2 | 430d? | 2003-11-03 A | 2005-06-24 | 90% | 43d? | 135d | finish no earlier than 2005-06-24 | GP-G2 | 3440h | 3096h | SPSHAGB-Stage2 | Gunnar Hedby, Ericsson | gunnar.hedby@ericsson.com | Rel-6 | Paolo | 43.129 |
| 385 | 62.2 | PS handover | 430d? | 2003-11-03 A | 2005-06-24 | 90% | 43d? | 135d | finish no earlier than 2005-06-24 | GP-G2 | 3440h | 3096h | SPSHAGB-PSHO | Gunnar Hedby, Ericsson | gunnar.hedby@ericsson.com | Rel-6 | Paolo |  |
| 386 | 62.3 | Definition of radio resource management functionality | 430d? | 2003-11-03 A | 2005-06-24 | 90% | 43d? | 135d | finish no earlier than 2005-06-24 | GP-G2 | 3440h | 3096h | SPSHAGB-RRM | Gunnar Hedby, Ericsson | gunnar.hedby@ericsson.com | Rel-6 | Paolo |  |
| 387 | 63 | Enhancements of VGCS in public networks for communication of public authority officials | 259d? | 2004-08-27 A | 2005-08-24 | 5% | 246.05d? | 92d | finish no earlier than 2005-08-24 | GP-G2 | 2072h | 103.6h | EVGCS | Ken Isaacs (Siemens) | kenneth.isaacs@roke.co.uk | Rel-6 | Gert | 44.018, 44.068, 48.008 |

Notes:
- 383: Replaces SCSAGB- Originally Started Nov 2003 as GP-030443
- 384: Replaces SCSAGB-Stage2
- 385: Replaces SCSAGB-PSH
- 386: Replaces SCSAGB-RRM
- 387: Started
